# Major Projects Schedule Template

Schedule from MS Project, 2010-06-07 to 2014-01-09.
UH

## Calendars

- Standard: Mon-Fri 08:00-12:00, 13:00-17:00; Sat-Sun off.

## Resources

| Resource |
| --- |
| A/E (Design) |
| CM-R |
| FP&C Sr. PM |
| FP&C PPM |
| UH Client |
| UH AVP/AVC |
| FP&C Exec Director |
| UH Pres/Chancellor |
| A/E (Programming) |
| UH Fire Marshal |
| Project Team |
| FP&C Planning |
| Purchasing |
| FP&C Facilities Info |
| 59 |
| Inspection Services |
| Art Committee |
| Business Services |
| OGC |
| Contractor |

## Schedule

| ID | WBS | Task | Type | Duration | Start | Finish | Predecessors | Total slack | Resources | Work |
| --- | --- | --- | --- | --- | --- | --- | --- | --- | --- | --- |
| 1 | 1 | **PROJECT DELIVERY SCHEDULE TEMPLATE (ALL STEPS)** |  | 939d? | 2010-06-07 | 2014-01-09 |  | 0d |  | 20680h |
| 2 | 1.1 | **PROJECT MILESTONES** |  | 717d | 2010-06-07 | 2013-03-05 |  | 222d |  |  |
| 3 | 1.1.1 | Project Initiation | milestone | 0d | 2010-06-07 | 2010-06-07 | 23SS | 940d | UH Client |  |
| 4 | 1.1.2 | Programming Kick-off | milestone | 0d | 2010-08-11 | 2010-08-11 | 36SS | 892d | FP&C Planning |  |
| 5 | 1.1.3 | Programming Complete | milestone | 0d | 2010-10-06 | 2010-10-06 | 43SS | 852d | FP&C Exec Director |  |
| 6 | 1.1.4 | CFPC Site Approval (Req'd. for Projects > $4M) | milestone | 0d | 2010-10-14 | 2010-10-14 | 47SS | 847d | FP&C Exec Director |  |
| 7 | 1.1.5 | BoR Agenda Item Due Date (Req'd. for Projects > $4M) | milestone | 0d | 2010-10-21 | 2010-10-21 | 49SS | 842d | FP&C Planning |  |
| 8 | 1.1.6 | BoR Approval (Req'd. for Projects > $4M) | milestone | 0d | 2010-10-28 | 2010-10-28 | 50SS | 837d | FP&C Exec Director |  |
| 9 | 1.1.7 | Design Kick-off | milestone | 0d | 2010-12-17 | 2010-12-17 | 112SS | 800d | FP&C Sr. PM |  |
| 10 | 1.1.8 | THECB Application Due Date (Req'd. for Projects > $4M) | milestone | 0d | 2010-12-22 | 2010-12-22 | 53SS | 797d | FP&C Facilities Info |  |
| 11 | 1.1.9 | THECB Approval (Req'd. for Projects > $4M) | milestone | 0d | 2011-02-16 | 2011-02-16 | 55SS | 757d | FP&C Facilities Info |  |
| 12 | 1.1.10 | Schematic Design Complete | milestone | 0d | 2011-02-14 | 2011-02-14 | 119SS | 759d | FP&C Sr. PM |  |
| 13 | 1.1.11 | CFPC Design Approval (Req'd. for Projects > $4M) | milestone | 0d | 2010-10-14 | 2010-10-14 | 47SS | 846d | FP&C Sr. PM |  |
| 14 | 1.1.12 | Design Development Complete | milestone | 0d | 2011-06-16 | 2011-06-16 | 126SS | 671d | FP&C Sr. PM |  |
| 15 | 1.1.13 | Design Complete | milestone | 0d | 2011-08-18 | 2011-08-18 | 131SS | 625d | A/E (Design) |  |
| 16 | 1.1.14 | Issue 30% CD's for GMP | milestone | 0d | 2011-06-23 | 2011-06-23 | 134 | 666d | A/E (Design) |  |
| 17 | 1.1.15 | GMP Approved | milestone | 0d | 2011-08-04 | 2011-08-04 | 137 | 636d | FP&C Sr. PM |  |
| 18 | 1.1.16 | Construction NTP Issued | milestone | 0d | 2011-12-08 | 2011-12-08 | 138, 152 | 545d | FP&C Sr. PM |  |
| 19 | 1.1.17 | Substantial Completion | milestone | 0d | 2013-01-10 | 2013-01-10 | 173 | 260d | FP&C Sr. PM |  |
| 20 | 1.1.18 | Final Occupancy | milestone | 0d | 2013-01-31 | 2013-01-31 | 183 | 245d | FP&C Sr. PM |  |
| 21 | 1.1.19 | Project Final Closeout | milestone | 0d | 2013-03-05 | 2013-03-05 | 191 | 222d | FP&C Sr. PM |  |
| 22 | 1.2 | **STEP 1 NEED DEVELOPMENT** |  | 15d | 2010-06-07 | 2010-06-25 |  | 0d |  | 120h |
| 23 | 1.2.1 | ND1 Electronic Project Request Form (MCPRF) submitted | milestone | 0d | 2010-06-07 | 2010-06-07 |  | 0d | FP&C Sr. PM |  |
| 24 | 1.2.2 | ND4 Preliminary Assessment |  | 15d | 2010-06-07 | 2010-06-25 | 23 | 0d | FP&C Exec Director | 120h |

| ID | WBS | Task | Type | Duration | Start | Finish | Predecessors | Total slack | Free slack | Resources | Work |
| --- | --- | --- | --- | --- | --- | --- | --- | --- | --- | --- | --- |
| 25 | 1.3 | **STEP 2 SCOPE DEVELOPMENT** |  | 73d | 2010-06-28 | 2010-10-06 | 24 | 0d |  |  | 1264h |
| 26 | 1.3.1 | SD1 PFA Form complete & Obtain Seed Funding |  | 5d | 2010-06-28 | 2010-07-02 |  | 0d |  | Business Services | 40h |
| 27 | 1.3.2 | **SD4 CSA for programming consultant services** |  | 28d | 2010-07-05 | 2010-08-11 |  | 0d |  | FP&C Planning | 464h |
| 28 | 1.3.2.1 | Write RFP for Programming |  | 3d | 2010-07-05 | 2010-07-07 | 26 | 0d |  | FP&C Planning | 24h |
| 29 | 1.3.2.2 | Select A/E from IDIQ List |  | 1d | 2010-07-05 | 2010-07-05 | 28SS | 2d |  | FP&C Planning | 8h |
| 30 | 1.3.2.3 | Issue RFP to A/E Firm |  | 1d | 2010-07-08 | 2010-07-08 | 28, 29 | 0d |  | FP&C Planning | 8h |
| 31 | 1.3.2.4 | A/E Prepare RFP Response |  | 10d | 2010-07-08 | 2010-07-21 | 30SS | 0d |  | A/E (Programming) | 80h |
| 32 | 1.3.2.5 | Negotiate Fee/Agreement |  | 5d | 2010-07-22 | 2010-07-28 | 31 | 0d |  | FP&C Planning | 40h |
| 33 | 1.3.2.6 | Issue & Execute Agreement |  | 10d | 2010-07-29 | 2010-08-11 | 32 | 0d |  | FP&C Planning | 80h |
| 34 | 1.3.3 | SD24 NTP to programming CSA Vendor | milestone | 0d | 2010-08-11 | 2010-08-11 | 33 | 0d |  | FP&C Planning |  |
| 35 | 1.3.4 | **SD26 Project Program Developed** |  | 35d | 2010-08-11 | 2010-09-29 | 26, 33, 34 | 0d |  | FP&C Planning | 720h |
| 36 | 1.3.4.1 | Programming Kick-off Meeting | milestone | 0d | 2010-08-11 | 2010-08-11 | 32FS-5d | 0d |  | FP&C Planning |  |
| 37 | 1.3.4.2 | A/E prepares basic documents & program narrative |  | 30d | 2010-08-12 | 2010-09-22 | 36 | 0d |  | A/E (Programming) | 240h |
| 38 | 1.3.4.3 | Space inventory & confirmation |  | 10d | 2010-09-09 | 2010-09-22 | 37FS-10d | 0d |  | A/E (Programming) | 80h |
| 39 | 1.3.4.4 | Equipment/Furniture inventory & confirmation |  | 10d | 2010-09-09 | 2010-09-22 | 38SS | 0d |  | A/E (Programming) | 80h |
| 40 | 1.3.4.5 | Project Control Budget/Milestone Schedule Confirmation |  | 5d | 2010-09-23 | 2010-09-29 | 39 | 0d |  | FP&C Sr. PM | 40h |
| 41 | 1.3.5 | SD29 Approval Meeting with User and Client on program | milestone | 0d | 2010-09-29 | 2010-09-29 | 40 | 0d |  | FP&C Sr. PM |  |
| 42 | 1.3.6 | SD31 Project Control Budget and Schedule Developed based upon program & Client input |  | 5d | 2010-09-30 | 2010-10-06 | 41 | 0d |  | FP&C Sr. PM | 40h |
| 43 | 1.3.7 | ED Approved Project to Move Forward | milestone | 0d | 2010-10-06 | 2010-10-06 | 42 | 0d |  | FP&C Exec Director |  |
| 44 | 1.4 | **STEP 3 SCOPE APPROVAL** |  | 95d | 2010-10-07 | 2011-02-16 |  | 176d |  |  | 1440h |
| 45 | 1.4.1 | SA2 Business Services Obtains Funding Sources & Notifies PPM that account is created |  | 5d | 2010-10-07 | 2010-10-13 | 43 | 177d | 0d | Business Services | 40h |
| 46 | 1.4.2 | Does Project Effect Land or Exterior Façade Changes? (YES Go to SA4/ NO Go to ?) | milestone | 0d | 2010-10-13 | 2010-10-13 | 45 | 177d | 0d | FP&C Sr. PM |  |
| 47 | 1.4.3 | SA4 CFPC Site Review/Approval (Projects > $4M & Land or Exterior Façade Changes) |  | 5d | 2010-10-14 | 2010-10-20 | 46 | 177d | 0d | FP&C Sr. PM | 40h |
| 48 | 1.4.4 | **SA6 Board Approval Process (Req'd. for Projects > $4M)** |  | 35d | 2010-10-21 | 2010-12-08 | 47 | 176d |  | FP&C Exec Director | 560h |
| 49 | 1.4.4.1 | BoR agenda item prep & submission |  | 5d | 2010-10-21 | 2010-10-27 | 47 | 177d | 0d | FP&C Planning | 40h |
| 50 | 1.4.4.2 | BoR review and approval |  | 30d | 2010-10-28 | 2010-12-08 | 49 | 177d | 0d | FP&C Exec Director | 240h |

| ID | WBS | Task | Type | Duration | Start | Finish | Predecessors | Total slack | Free slack | Resources | Work |
| --- | --- | --- | --- | --- | --- | --- | --- | --- | --- | --- | --- |
| 51 | 1.4.5 | **THECB Approval (Req'd. for Projects > $4M) [MUST OCCUR BEFORE STEP 6]** |  | 50d | 2010-12-09 | 2011-02-16 | 50 | 176d |  | FP&C Exec Director | 800h |
| 52 | 1.4.5.1 | Create THECB Draft Application (internal FP&C) |  | 10d | 2010-12-09 | 2010-12-22 | 50 | 177d | 0d | FP&C Facilities Info | 80h |
| 53 | 1.4.5.2 | Submit THECB Application (internal FP&C) | milestone | 0d | 2010-12-22 | 2010-12-22 | 52 | 177d | 0d | FP&C Facilities Info |  |
| 54 | 1.4.5.3 | THECB Project Review & Evaluation Deadline |  | 40d | 2010-12-23 | 2011-02-16 | 53, 52 | 177d | 0d | FP&C Facilities Info | 320h |
| 55 | 1.4.5.4 | THECB Full Board Meeting/Approval | milestone | 0d | 2011-02-16 | 2011-02-16 | 54, 49, 50, 23 | 177d | 0d | FP&C Facilities Info |  |
| 56 | 1.5 | **STEP 4 QUALIFICATIONS BASED SELECTION** |  | 122d | 2010-10-07 | 2011-03-25 |  | 0d |  |  | 4176h |
| 57 | 1.5.1 | **Step 4 Design Team Selection Process (Can occur parallel to Programming effort or after ED approvel to move forward)** |  | 52d | 2010-10-07 | 2010-12-17 |  | 0d |  | FP&C Exec Director | 1152h |
| 58 | 1.5.1.1 | **DT1 Write RFQ & Evaluation Criteria** |  | 37d | 2010-10-07 | 2010-11-26 | 43 | 0d |  | FP&C Sr. PM | 608h |
| 59 | 1.5.1.1.1 | DT4 ED Approves RFQ |  | 5d | 2010-10-07 | 2010-10-13 | 43 | 0d |  | FP&C Exec Director | 40h |
| 60 | 1.5.1.1.2 | DT5 OGC Reviews and Approves RFQ | milestone | 0d | 2010-10-13 | 2010-10-13 | 59 | 0d |  | OGC |  |
| 61 | 1.5.1.1.3 | DT9 Post RFQ on ESBD |  | 17d | 2010-10-14 | 2010-11-05 | 60 | 0d |  | Purchasing | 136h |
| 62 | 1.5.1.1.4 | DT10 Pre-submittal conference |  | 5d | 2010-10-28 | 2010-11-03 | 61SS+10d | 0d |  | Purchasing | 40h |
| 63 | 1.5.1.1.5 | DT12 Purchasing/Business Distribute RFQ responses to committee |  | 1d | 2010-11-11 | 2010-11-11 | 62FS+5d | 0d |  | Business Services | 8h |
| 64 | 1.5.1.1.6 | DT14 Evaluate and rank RFQ submittals |  | 8d | 2010-11-12 | 2010-11-23 | 63 | 0d |  | FP&C Sr. PM | 64h |
| 65 | 1.5.1.1.7 | DT18 Select short list |  | 3d | 2010-11-24 | 2010-11-26 | 64 | 1d | 0d | FP&C Sr. PM | 24h |
| 66 | 1.5.1.2 | **DT21 Conduct interviews** |  | 2d | 2010-11-29 | 2010-11-30 | 65 | 0d |  | FP&C Sr. PM | 24h |
| 67 | 1.5.1.2.1 | DT22 Send Committee evaluations to purchasing |  | 1d | 2010-11-29 | 2010-11-29 | 65 | 1d |  | FP&C Sr. PM | 8h |
| 68 | 1.5.1.2.2 | DT25 Purchasing drafts recommendation and sendt o EVP for approval | milestone | 0d | 2010-11-30 | 2010-11-30 | 64FS+5d, 67 | 0d |  | Purchasing |  |
| 69 | 1.5.1.3 | DT26 Purchasing Notifies Successful Vendor |  | 3d | 2010-12-01 | 2010-12-03 | 68 | 0d |  | UH AVP/AVC | 24h |
| 70 | 1.5.1.4 | DT29 Fee Proposal Confirmed with Vendor |  | 10d | 2010-12-06 | 2010-12-17 | 69 | 0d |  | FP&C Sr. PM | 80h |
| 71 | 1.5.2 | **Step 4 Design Build Team Selection Process** |  | 100d | 2010-10-07 | 2011-02-23 | 43 | 171d |  | FP&C Sr. PM | 1632h |
| 72 | 1.5.2.1 | **DB1 Write RFQ & Evaluation Criteria** |  | 27d | 2010-10-07 | 2010-11-12 | 43 | 171d |  | FP&C Sr. PM | 384h |
| 73 | 1.5.2.1.1 | DB4 ED Approves RFQ |  | 5d | 2010-10-07 | 2010-10-13 | 43 | 172d | 0d | FP&C Exec Director | 40h |
| 74 | 1.5.2.1.2 | DB5 OGC Reviews and Approves RFQ | milestone | 0d | 2010-10-13 | 2010-10-13 | 73 | 171d | 0d | OGC |  |
| 75 | 1.5.2.1.3 | DB9 Post RFQ on ESBD |  | 2d | 2010-10-14 | 2010-10-15 | 74 | 172d | 0d | Purchasing | 16h |
| 76 | 1.5.2.1.4 | DB10 Pre-submittal conference |  | 5d | 2010-10-21 | 2010-10-27 | 75FS+3d | 171d | 0d | Purchasing | 40h |
| 77 | 1.5.2.1.5 | DB13 Purchasing/Business Distribute RFQ responses to committee |  | 1d | 2010-11-02 | 2010-11-02 | 76FS+3d | 172d | 0d | Business Services | 8h |
| 78 | 1.5.2.1.6 | DB15 Evaluate and rank RFQ submittals & determines firms to receive RFP |  | 8d | 2010-11-03 | 2010-11-12 | 77 | 172d | 0d | FP&C Sr. PM | 64h |

| ID | WBS | Task | Type | Duration | Start | Finish | Predecessors | Total slack | Free slack | Resources | Work |
| --- | --- | --- | --- | --- | --- | --- | --- | --- | --- | --- | --- |
| 79 | 1.5.2.2 | **DB19 Write RFP and evaluation criteria [RFP PROCESS]** |  | 25d | 2010-11-29 | 2010-12-31 | 78 | 171d |  | FP&C Sr. PM | 280h |
| 80 | 1.5.2.2.1 | DB20 ED Approves RFP |  | 10d | 2010-11-29 | 2010-12-10 | 78FS+10d | 172d | 0d | FP&C Exec Director | 80h |
| 81 | 1.5.2.2.2 | DB21 OGC Reviews and Approves RFP | milestone | 0d | 2010-12-10 | 2010-12-10 | 80 | 171d | 0d | OGC |  |
| 82 | 1.5.2.2.3 | DB25 Purchasing issues RFP to short listed firms | milestone | 0d | 2010-12-17 | 2010-12-17 | 81SS+5d | 171d | 0d | Purchasing |  |
| 83 | 1.5.2.2.4 | DB29 Purchasing/Business Distribute RFP responses to committee | milestone | 0d | 2010-12-31 | 2010-12-31 | 82FS+10d | 171d | 0d | Business Services |  |
| 84 | 1.5.2.3 | **DB34 Conduct interviews** |  | 5d | 2011-01-07 | 2011-01-14 | 83 | 171d |  | FP&C Sr. PM | 64h |
| 85 | 1.5.2.3.1 | DB35 Send Committee evaluations to purchasing | milestone | 0d | 2011-01-07 | 2011-01-07 | 83FS+5d | 171d | 0d | FP&C Sr. PM |  |
| 86 | 1.5.2.3.2 | DB38 Purchasing drafts recommendation and sendt o EVP for approval | milestone | 0d | 2011-01-11 | 2011-01-11 | 85FS+2d | 171d | 0d | Purchasing |  |
| 87 | 1.5.2.3.3 | DB39 Purchasing Notifies Successful Vendor |  | 3d | 2011-01-12 | 2011-01-14 | 86 | 172d | 0d | UH AVP/AVC | 24h |
| 88 | 1.5.2.4 | DB40 Fee Proposal Confirmed with Vendor |  | 10d | 2011-01-17 | 2011-01-28 | 87 | 172d | 0d | FP&C Sr. PM | 80h |
| 89 | 1.5.2.5 | DB47 CC prepares contract and sends for signatures |  | 3d | 2011-02-14 | 2011-02-16 | 88FS+10d | 172d | 0d | Business Services | 24h |
| 90 | 1.5.2.6 | DB54 CC sends vendor & PM executed contract & NTP | milestone | 0d | 2011-02-23 | 2011-02-23 | 89FS+5d, 55 | 172d | 81d | Business Services |  |
| 91 | 1.5.3 | **Step 4 CM@Risk Two Step Selection Process (Selection complete before start of SD's)** |  | 80d | 2010-12-06 | 2011-03-25 | 70SS | 149d |  | FP&C Sr. PM | 1392h |
| 92 | 1.5.3.1 | **CM1 Write RFQ & Evaluation Criteria** |  | 27d | 2010-12-06 | 2011-01-11 | 70SS | 149d |  | FP&C Sr. PM | 384h |
| 93 | 1.5.3.1.1 | CM4 ED Approves RFQ |  | 5d | 2010-12-06 | 2010-12-10 | 43 | 149d | 0d | FP&C Exec Director | 40h |
| 94 | 1.5.3.1.2 | CM5 OGC Reviews and Approves RFQ | milestone | 0d | 2010-12-10 | 2010-12-10 | 93 | 149d | 0d | OGC |  |
| 95 | 1.5.3.1.3 | CM9 Post RFQ on ESBD |  | 2d | 2010-12-13 | 2010-12-14 | 94 | 130d | 0d | Purchasing | 16h |
| 96 | 1.5.3.1.4 | CM10 Pre-submittal conference |  | 5d | 2010-12-20 | 2010-12-24 | 95FS+3d | 149d | 0d | Purchasing | 40h |
| 97 | 1.5.3.1.5 | CM13 Purchasing/Business Distribute RFQ responses to committee |  | 1d | 2010-12-30 | 2010-12-30 | 96FS+3d | 130d | 0d | Business Services | 8h |
| 98 | 1.5.3.1.6 | CM15 Evaluate and rank RFQ submittals & determines firms to receive RFP |  | 8d | 2010-12-31 | 2011-01-11 | 97 | 130d | 0d | Purchasing | 64h |
| 99 | 1.5.3.2 | **CM19 Write RFP and evaluation criteria [RFP PROCESS]** |  | 25d | 2011-01-26 | 2011-03-01 | 98 | 149d |  | FP&C Sr. PM | 280h |
| 100 | 1.5.3.2.1 | CM20 ED Approves RFP |  | 10d | 2011-01-26 | 2011-02-08 | 98FS+10d | 130d | 0d | FP&C Exec Director | 80h |
| 101 | 1.5.3.2.2 | CM21 OGC Reviews and Approves RFP | milestone | 0d | 2011-02-08 | 2011-02-08 | 100 | 149d | 0d | OGC |  |
| 102 | 1.5.3.2.3 | CM25 Purchasing issues RFP to short listed firms | milestone | 0d | 2011-02-15 | 2011-02-15 | 101SS+5d | 149d | 0d | Purchasing |  |
| 103 | 1.5.3.2.4 | CM29 Purchasing/Business Distribute RFP responses to committee | milestone | 0d | 2011-03-01 | 2011-03-01 | 102FS+10d | 149d | 0d | Business Services |  |

| ID | WBS | Task | Type | Duration | Start | Finish | Predecessors | Total slack | Free slack | Resources | Work |
| --- | --- | --- | --- | --- | --- | --- | --- | --- | --- | --- | --- |
| 104 | 1.5.3.3 | **CM34 Conduct interviews** |  | 5d | 2011-03-08 | 2011-03-15 | 103FS+5d | 149d |  | FP&C Sr. PM | 64h |
| 105 | 1.5.3.3.1 | CM35 Send Committee evaluations to purchasing | milestone | 0d | 2011-03-08 | 2011-03-08 | 103FS+5d | 149d | 0d | FP&C Sr. PM |  |
| 106 | 1.5.3.3.2 | CM38 Purchasing drafts recommendation and sendt o EVP for approval | milestone | 0d | 2011-03-10 | 2011-03-10 | 105FS+2d | 149d | 0d | Purchasing |  |
| 107 | 1.5.3.3.3 | CM39 Purchasing Notifies Successful Vendor |  | 3d | 2011-03-11 | 2011-03-15 | 106 | 130d | 0d | Purchasing | 24h |
| 108 | 1.5.3.4 | CM48 CC prepares contract and sends for signatures |  | 3d | 2011-03-16 | 2011-03-18 | 107 | 149d | 0d | Business Services | 24h |
| 109 | 1.5.3.5 | CM54 CC sends vendor & PM executed contract & NTP | milestone | 0d | 2011-03-25 | 2011-03-25 | 108FS+5d, 55 | 149d | 59d | Business Services |  |
| 110 | 1.6 | **STEP 4 DESIGN PROCESS** |  | 174d | 2010-12-17 | 2011-08-18 |  | 0d |  |  | 2800h |
| 111 | 1.6.1 | **D1 Pre Design** |  | 0d | 2010-12-17 | 2010-12-17 | 70 | 0d |  | FP&C Sr. PM |  |
| 112 | 1.6.1.1 | D1 Design Kick-off Meeting & Confirm Deliverables | milestone | 0d | 2010-12-17 | 2010-12-17 | 70 | 0d |  | FP&C Sr. PM |  |
| 113 | 1.6.1.2 | D2 NTP to Commence Design | milestone | 0d | 2010-12-17 | 2010-12-17 | 112 | 0d |  | FP&C Sr. PM |  |
| 114 | 1.6.2 | **D3 Schematic Design** |  | 42d | 2010-12-20 | 2011-02-15 | 113 | 0d |  | FP&C Sr. PM | 672h |
| 115 | 1.6.2.1 | D4 Issue 95% SD for Review & Comment |  | 30d | 2010-12-20 | 2011-01-28 | 113 | 0d |  | A/E (Design) | 240h |
| 116 | 1.6.2.2 | D8 Prepare budget check based on 95% SD's |  | 10d | 2011-01-31 | 2011-02-11 | 115 | 0d |  | CM-R | 80h |
| 117 | 1.6.2.3 | D7 Confirm SD compliance w/ approved program |  | 1d | 2011-02-14 | 2011-02-14 | 116 | 0d |  | A/E (Design) | 8h |
| 118 | 1.6.2.4 | D9 User Sign-off of SD's |  | 1d | 2011-02-15 | 2011-02-15 | 117 | 39d |  | FP&C Sr. PM | 8h |
| 119 | 1.6.2.5 | D10 Issue NTP for DD phase | milestone | 0d | 2011-02-14 | 2011-02-14 | 117 | 0d |  | FP&C Sr. PM |  |
| 120 | 1.6.3 | **D11 Design Development** |  | 88d | 2011-02-15 | 2011-06-16 | 119 | 0d |  | FP&C Sr. PM | 1408h |
| 121 | 1.6.3.1 | D12 FIS develops furniture plan & Room Numbering |  | 10d | 2011-02-15 | 2011-02-28 | 119 | 0d |  | FP&C Sr. PM | 80h |
| 122 | 1.6.3.2 | D13 Issue 50% DD for Review & Comment |  | 30d | 2011-03-01 | 2011-04-11 | 115, 118FF, 121 | 0d |  | A/E (Design) | 240h |
| 123 | 1.6.3.3 | D18 Submit for CFPC Design Approval (Projects > $4M) |  | 3d | 2011-04-12 | 2011-04-14 | 122 | 0d |  | FP&C Sr. PM | 24h |
| 124 | 1.6.3.4 | D22 Issue 95% DD for Review & Comment |  | 30d | 2011-04-15 | 2011-05-26 | 123 | 0d |  | A/E (Design) | 240h |
| 125 | 1.6.3.5 | D26 Prepare budget check based on 95% DD's |  | 15d | 2011-05-27 | 2011-06-16 | 124 | 0d |  | CM-R | 120h |
| 126 | 1.6.3.6 | D28 Issue NTP for CD phase | milestone | 0d | 2011-06-16 | 2011-06-16 | 125 | 0d |  | FP&C Sr. PM |  |
| 127 | 1.6.4 | **D29 Construction Documents** |  | 45d | 2011-06-17 | 2011-08-18 | 126 | 0d |  | FP&C Sr. PM | 720h |
| 128 | 1.6.4.1 | D37 Issue 50% CD's for Review and Comment |  | 40d | 2011-06-17 | 2011-08-11 | 126 | 0d |  | A/E (Design) | 320h |
| 129 | 1.6.4.2 | D40 Final Confirmation of Design to Program |  | 5d | 2011-08-12 | 2011-08-18 | 128 | 0d |  | A/E (Design) | 40h |
| 130 | 1.6.4.3 | D41 Issue 95% CD's for review & comment | milestone | 0d | 2011-08-18 | 2011-08-18 | 129 | 0d |  | A/E (Design) |  |
| 131 | 1.6.4.4 | Design Complete, Issue 100% CD's for construction | milestone | 0d | 2011-08-18 | 2011-08-18 | 130 | 0d |  | A/E (Design) |  |

| ID | WBS | Task | Type | Duration | Start | Finish | Predecessors | Total slack | Free slack | Resources | Work |
| --- | --- | --- | --- | --- | --- | --- | --- | --- | --- | --- | --- |
| 132 | 1.7 | **STEP 5 BID/PURCHASE** |  | 125d | 2011-06-17 | 2011-12-08 |  | 0d |  |  | 1448h |
| 133 | 1.7.1 | **Step 5 Guaranteed Maximum Price Process** |  | 35d | 2011-06-17 | 2011-08-04 | 126, 109, 90 | 90d |  | FP&C Sr. PM | 400h |
| 134 | 1.7.1.1 | GMP1 Confirmation Project Defined to establish GMP |  | 5d | 2011-06-17 | 2011-06-23 | 126, 109, 90 | 91d | 0d | A/E (Design) | 40h |
| 135 | 1.7.1.2 | GMP4 PM prepares GMP proposal | milestone | 0d | 2011-07-21 | 2011-07-21 | 134FS+20d | 90d | 0d | CM-R |  |
| 136 | 1.7.1.3 | GMP7 FP&C & A/E Review GMP |  | 5d | 2011-07-22 | 2011-07-28 | 135 | 91d | 0d | FP&C Sr. PM | 40h |
| 137 | 1.7.1.4 | GMP8 FP&C issues Contract Change for GMP |  | 5d | 2011-07-29 | 2011-08-04 | 136 | 90d | 0d | FP&C Sr. PM | 40h |
| 138 | 1.7.1.5 | GMP20 NTP for construction | milestone | 0d | 2011-08-04 | 2011-08-04 | 137 | 90d |  | FP&C Sr. PM |  |
| 139 | 1.7.2 | **Step 5 Contractor CSP Selection Process** |  | 70d | 2011-09-02 | 2011-12-08 | 131 | 0d |  | FP&C Sr. PM | 1048h |
| 140 | 1.7.2.1 | **CSP2 Write RFP and evaluation criteria [RFP PROCESS]** |  | 32d | 2011-09-02 | 2011-10-17 | 131 | 0d |  | FP&C Sr. PM | 320h |
| 141 | 1.7.2.1.1 | CSP4 ED Approves RFP |  | 5d | 2011-09-02 | 2011-09-08 | 131FS+10d | 0d |  | FP&C Exec Director | 40h |
| 142 | 1.7.2.1.2 | CSP5 OGC Reviews and Approves RFP |  | 3d | 2011-09-09 | 2011-09-13 | 141 | 0d |  | OGC | 24h |
| 143 | 1.7.2.1.3 | CSP9 Purchasing Posts RFP to ESBD | milestone | 0d | 2011-09-14 | 2011-09-14 | 142FS+1d | 0d |  | Purchasing |  |
| 144 | 1.7.2.1.4 | CSP14 Purchasing/Business Distribute RFQ responses to committee | milestone | 0d | 2011-10-12 | 2011-10-12 | 143FS+20d | 0d |  | Business Services |  |
| 145 | 1.7.2.1.5 | CSP16 Purchasing Notifies Shortlisted firms of Interview | milestone | 0d | 2011-10-17 | 2011-10-17 | 144FS+3d | 0d |  | Purchasing |  |
| 146 | 1.7.2.2 | **CSP19 Conduct interviews** |  | 5d | 2011-10-24 | 2011-10-31 | 145 | 0d |  | FP&C Sr. PM | 64h |
| 147 | 1.7.2.2.1 | CSP20 Send Committee evaluations to purchasing | milestone | 0d | 2011-10-24 | 2011-10-24 | 145FS+5d | 0d |  | FP&C Sr. PM |  |
| 148 | 1.7.2.2.2 | CSP23 Purchasing drafts recommendation and sendt o EVP for approval | milestone | 0d | 2011-10-26 | 2011-10-26 | 147FS+2d | 0d |  | Purchasing |  |
| 149 | 1.7.2.2.3 | CSP24 Purchasing Notifies Successful Vendor |  | 3d | 2011-10-27 | 2011-10-31 | 148 | 0d |  | Purchasing | 24h |
| 150 | 1.7.2.3 | CSP25 PM finalizes contract terms with successful vendor |  | 10d | 2011-11-01 | 2011-11-14 | 149 | 0d |  | FP&C Sr. PM | 80h |
| 151 | 1.7.2.4 | CSP33 CC prepares contract and sends for signatures |  | 3d | 2011-11-29 | 2011-12-01 | 150FS+10d | 0d |  | Business Services | 24h |
| 152 | 1.7.2.5 | CSP39 CC sends vendor & PM executed contract & NTP | milestone | 0d | 2011-12-08 | 2011-12-08 | 151FS+5d | 0d |  | Business Services |  |
| 153 | 1.8 | **STEP6 CONSTRUCTION PHASE** |  | 285d | 2011-12-09 | 2013-01-10 |  | 0d |  |  | 4200h |
| 154 | 1.8.1 | C1 PM confirms site ready to commence construction |  | 5d | 2011-12-09 | 2011-12-15 | 55, 152, 138 | 0d |  | FP&C Sr. PM | 40h |
| 155 | 1.8.2 | C2 Conduct Pre-construction/Kick-off Meeting | milestone | 0d | 2011-12-29 | 2011-12-29 | 154FS+10d | 0d |  | FP&C Sr. PM |  |
| 156 | 1.8.3 | C4 PM, PPM review baseline schedule & Schedule of Values |  | 10d | 2011-12-30 | 2012-01-12 | 155 | 0d |  | FP&C Sr. PM | 80h |
| 157 | 1.8.4 | C5 Construction Period |  | 260d | 2012-01-13 | 2013-01-10 | 156 | 0d |  | CM-R | 2080h |
| 158 | 1.8.5 | C6 Perform Inspections during Construction Period |  | 250d | 2012-01-27 | 2013-01-10 | 157SS+10d | 0d |  | Inspection Services | 2000h |

| ID | WBS | Task | Type | Duration | Start | Finish | Predecessors | Total slack | Free slack | Resources | Work |
| --- | --- | --- | --- | --- | --- | --- | --- | --- | --- | --- | --- |
| 159 | 1.9 | **ACTIVATION & CLOSEOUT** |  | 305d? | 2012-11-09 | 2014-01-09 |  | 0d |  |  | 5232h |
| 160 | 1.9.1 | **TAC1 Perform Transition Planning Kick off Meeting** |  | 20d | 2012-11-09 | 2012-12-06 | 157FS-45d | 255d |  | FP&C Sr. PM | 664h |
| 161 | 1.9.1.1 | IT Install & Activation |  | 20d | 2012-11-09 | 2012-12-06 | 157FS-45d | 255d | 0d | FP&C Sr. PM | 160h |
| 162 | 1.9.1.2 | Furniture & Furnishings Coordination |  | 10d | 2012-11-09 | 2012-11-22 | 161SS | 265d | 50d | FP&C Sr. PM | 80h |
| 163 | 1.9.1.3 | Keying Coordination |  | 20d | 2012-11-09 | 2012-12-06 | 161SS | 255d | 40d | FP&C Sr. PM | 160h |
| 164 | 1.9.1.4 | Grounds Coordination |  | 3d | 2012-11-09 | 2012-11-13 | 161SS | 272d | 57d | FP&C Sr. PM | 24h |
| 165 | 1.9.1.5 | Coordinate building turnover with UH Facilities Mgmt. |  | 10d | 2012-11-09 | 2012-11-22 | 161SS | 265d | 50d | FP&C Sr. PM | 80h |
| 166 | 1.9.2 | **TAC2 Perform Commissioning, Inspections & Equipment Certifications** |  | 25d | 2012-11-30 | 2013-01-03 | 157FS-30d | 5d |  | FP&C Sr. PM | 680h |
| 167 | 1.9.2.1 | Building occupancy certification/Fire Marshall inspections |  | 15d | 2012-11-30 | 2012-12-20 | 157FS-30d | 267d | 10d | CM-R | 120h |
| 168 | 1.9.2.2 | Building test & balance |  | 20d | 2012-11-30 | 2012-12-27 | 157FF-30d | 5d | 0d | FP&C Sr. PM | 160h |
| 169 | 1.9.2.3 | Building systems commissioning & testing |  | 20d | 2012-11-30 | 2012-12-27 | 157FF-30d | 5d | 0d | FP&C Sr. PM | 160h |
| 170 | 1.9.2.4 | BAS/DDC commissioning sign off/acceptance |  | 5d | 2012-12-28 | 2013-01-03 | 168, 169 | 5d | 0d | FP&C Sr. PM | 40h |
| 171 | 1.9.3 | **TAC3 Perform Substantial Completion Activities** |  | 25d | 2012-12-27 | 2013-01-31 |  | 10d |  | FP&C Sr. PM | 320h |
| 172 | 1.9.3.1 | Confirm Inspection Deficiencies Completed | milestone | 0d | 2012-12-27 | 2012-12-27 | 157FF-10d | 225d | 10d | Inspection Services |  |
| 173 | 1.9.3.2 | Substantial Completion | milestone | 0d | 2013-01-10 | 2013-01-10 | 157, 170, 158 | 0d |  | FP&C Sr. PM |  |
| 174 | 1.9.3.3 | Punch List Reconciliation |  | 15d | 2013-01-11 | 2013-01-31 | 173, 172 | 215d | 0d | CM-R | 120h |
| 175 | 1.9.4 | **TAC4 Install Signage, Wayfinding, Furniture & Art** |  | 11d? | 2013-01-11 | 2013-01-25 | 173 | 220d |  | FP&C Sr. PM | 256h |
| 176 | 1.9.4.1 | Install Signage & Wayfinding |  | 10d | 2013-01-11 | 2013-01-24 | 173 | 220d | 5d | FP&C Sr. PM | 80h |
| 177 | 1.9.4.2 | Furniture & Furnishings move-in |  | 10d | 2013-01-11 | 2013-01-24 | 173 | 220d | 0d | FP&C Sr. PM | 80h |
| 178 | 1.9.4.3 | Install Art |  | 1d? | 2013-01-25 | 2013-01-25 | 177 | 249d |  | Art Committee | 8h |
| 179 | 1.9.5 | **TAC5 Building Systems Training** |  | 5d | 2013-01-04 | 2013-01-10 | 170 | 257d |  | FP&C Sr. PM | 104h |
| 180 | 1.9.5.1 | Systems Training of FM by Contractor |  | 3d | 2013-01-04 | 2013-01-08 | 170 | 259d | 37d | CM-R | 24h |
| 181 | 1.9.5.2 | Life Safety Training by Contractor |  | 5d | 2013-01-04 | 2013-01-10 | 167 | 257d | 35d | CM-R | 40h |
| 182 | 1.9.6 | **TAC6 Contractor Performs Final Completion Activities** |  | 30d | 2013-01-31 | 2013-03-14 | 157, 161, 162, 165, 168, 169, 170, 173, 174, 177, 176, 163, 164 | 215d |  | FP&C Sr. PM | 480h |
| 183 | 1.9.6.1 | Final Occupancy | milestone | 0d | 2013-01-31 | 2013-01-31 | 157, 161, 162, 165, 168, 169, 170, 173, 174, 177, 176, 163, 164 | 215d | 0d | FP&C Sr. PM |  |
| 184 | 1.9.6.2 | 1st Day of Operations by End User/Client | milestone | 0d | 2013-01-31 | 2013-01-31 | 183 | 215d | 0d | FP&C Sr. PM |  |
| 185 | 1.9.6.3 | Conduct TDLR final inspection |  | 30d | 2013-02-01 | 2013-03-14 | 184 | 215d |  | A/E (Design) | 240h |

| ID | WBS | Task | Type | Duration | Start | Finish | Predecessors | Total slack | Free slack | Resources | Work |
| --- | --- | --- | --- | --- | --- | --- | --- | --- | --- | --- | --- |
| 186 | 1.9.7 | **TAC7 Perform Administrative Closeout** |  | 20d | 2013-02-01 | 2013-02-28 | 183 | 222d |  | FP&C Sr. PM | 360h |
| 187 | 1.9.7.1 | Construction Closeout Documents Complete |  | 20d | 2013-02-01 | 2013-02-28 | 183 | 222d | 0d | CM-R | 160h |
| 188 | 1.9.7.2 | Final Program Space Allocation Updated with BIS |  | 5d | 2013-02-01 | 2013-02-07 | 183 | 240d |  | Business Services | 40h |
| 189 | 1.9.8 | **TAC8 Perform Financial Closeout** |  | 23d | 2013-02-01 | 2013-03-05 | 183 | 222d |  | FP&C Sr. PM | 368h |
| 190 | 1.9.8.1 | Conduct Final Construction Audit |  | 20d | 2013-02-01 | 2013-02-28 | 183 | 222d | 0d | FP&C Sr. PM | 160h |
| 191 | 1.9.8.2 | Release Contractor Retainage |  | 3d | 2013-03-01 | 2013-03-05 | 190, 180, 181, 187 | 222d | 0d | FP&C Sr. PM | 24h |
| 192 | 1.9.9 | **TAC9 Warranty Period** |  | 245d | 2013-02-01 | 2014-01-09 | 190SS | 0d |  | FP&C Sr. PM | 2000h |
| 193 | 1.9.9.1 | Confirm Contractor Insurance Valid for Warranty Period | milestone | 0d | 2013-02-01 | 2013-02-01 | 190SS | 225d |  | Business Services |  |
| 194 | 1.9.9.2 | 11 Month Inspection |  | 5d | 2013-12-13 | 2013-12-19 | 173FS+240d, 193 | 0d |  | FP&C Sr. PM | 40h |
| 195 | 1.9.9.3 | Warranty Repairs Completed | milestone | 0d | 2014-01-09 | 2014-01-09 | 194SS+20d | 0d |  | Contractor |  |
| 196 | 1.9.10 | END OF PROJECT | milestone | 0d | 2014-01-09 | 2014-01-09 | 195, 178, 185, 188, 191 | 0d |  | FP&C Sr. PM |  |
