# Major Projects Schedule Template

Schedule from MS Project, 2010-06-07 to 2014-01-09.
UH

## Calendars

- Standard: Mon-Fri 08:00-12:00, 13:00-17:00; Sat-Sun off.

## Resources

| Resource |
| --- |
| A/E (Design) |
| CM-R |
| FP&C Sr. PM |
| FP&C PPM |
| UH Client |
| UH AVP/AVC |
| FP&C Exec Director |
| UH Pres/Chancellor |
| A/E (Programming) |
| UH Fire Marshal |
| Project Team |
| FP&C Planning |
| Purchasing |
| FP&C Facilities Info |
| 59 |
| Inspection Services |
| Art Committee |
| Business Services |
| OGC |
| Contractor |

## Schedule

| ID | WBS | Task | Type | Duration | Start | Finish | Predecessors | Total slack | Resources | Work |
| --- | --- | --- | --- | --- | --- | --- | --- | --- | --- | --- |
| 1 | 1 | **PROJECT DELIVERY SCHEDULE TEMPLATE (CSP)** |  | 939d? | 2010-06-07 | 2014-01-09 |  | 0d |  | 17256h |
| 2 | 1.1 | **PROJECT MILESTONES** |  | 717d | 2010-06-07 | 2013-03-05 |  | 222d |  |  |
| 3 | 1.1.1 | Project Initiation | milestone | 0d | 2010-06-07 | 2010-06-07 | 21SS | 940d | UH Client |  |
| 4 | 1.1.2 | Programming Kick-off | milestone | 0d | 2010-08-11 | 2010-08-11 | 34SS | 892d | FP&C Planning |  |
| 5 | 1.1.3 | Programming Complete | milestone | 0d | 2010-10-06 | 2010-10-06 | 41SS | 852d | FP&C Exec Director |  |
| 6 | 1.1.4 | CFPC Site Approval (Req'd. for Projects > $4M) | milestone | 0d | 2010-10-14 | 2010-10-14 | 45SS | 847d | FP&C Exec Director |  |
| 7 | 1.1.5 | BoR Agenda Item Due Date (Req'd. for Projects > $4M) | milestone | 0d | 2010-10-21 | 2010-10-21 | 47SS | 842d | FP&C Planning |  |
| 8 | 1.1.6 | BoR Approval (Req'd. for Projects > $4M) | milestone | 0d | 2010-10-28 | 2010-10-28 | 48SS | 837d | FP&C Exec Director |  |
| 9 | 1.1.7 | Design Kick-off | milestone | 0d | 2010-12-17 | 2010-12-17 | 71SS | 800d | FP&C Sr. PM |  |
| 10 | 1.1.8 | THECB Application Due Date (Req'd. for Projects > $4M) | milestone | 0d | 2010-12-22 | 2010-12-22 | 51SS | 797d | FP&C Facilities Info |  |
| 11 | 1.1.9 | THECB Approval (Req'd. for Projects > $4M) | milestone | 0d | 2011-02-16 | 2011-02-16 | 53SS | 757d | FP&C Facilities Info |  |
| 12 | 1.1.10 | Schematic Design Complete | milestone | 0d | 2011-02-14 | 2011-02-14 | 78SS | 759d | FP&C Sr. PM |  |
| 13 | 1.1.11 | CFPC Design Approval (Req'd. for Projects > $4M) | milestone | 0d | 2010-10-14 | 2010-10-14 | 45SS | 846d | FP&C Sr. PM |  |
| 14 | 1.1.12 | Design Development Complete | milestone | 0d | 2011-06-16 | 2011-06-16 | 85SS | 671d | FP&C Sr. PM |  |
| 15 | 1.1.13 | Design Complete | milestone | 0d | 2011-08-18 | 2011-08-18 | 90SS | 625d | A/E (Design) |  |
| 16 | 1.1.14 | Construction NTP Issued | milestone | 0d | 2011-12-08 | 2011-12-08 | 105 | 545d | FP&C Sr. PM |  |
| 17 | 1.1.15 | Substantial Completion | milestone | 0d | 2013-01-10 | 2013-01-10 | 126 | 260d | FP&C Sr. PM |  |
| 18 | 1.1.16 | Final Occupancy | milestone | 0d | 2013-01-31 | 2013-01-31 | 136 | 245d | FP&C Sr. PM |  |
| 19 | 1.1.17 | Project Final Closeout | milestone | 0d | 2013-03-05 | 2013-03-05 | 144 | 222d | FP&C Sr. PM |  |
| 20 | 1.2 | **STEP 1 NEED DEVELOPMENT** |  | 15d | 2010-06-07 | 2010-06-25 |  | 0d |  | 120h |
| 21 | 1.2.1 | ND1 Electronic Project Request Form (MCPRF) submitted | milestone | 0d | 2010-06-07 | 2010-06-07 |  | 0d | FP&C Sr. PM |  |
| 22 | 1.2.2 | ND4 Preliminary Assessment |  | 15d | 2010-06-07 | 2010-06-25 | 21 | 0d | FP&C Exec Director | 120h |
| 23 | 1.3 | **STEP 2 SCOPE DEVELOPMENT** |  | 73d | 2010-06-28 | 2010-10-06 | 22 | 0d |  | 1264h |
| 24 | 1.3.1 | SD1 PFA Form complete & Obtain Seed Funding |  | 5d | 2010-06-28 | 2010-07-02 |  | 0d | Business Services | 40h |

| ID | WBS | Task | Type | Duration | Start | Finish | Predecessors | Total slack | Free slack | Resources | Work |
| --- | --- | --- | --- | --- | --- | --- | --- | --- | --- | --- | --- |
| 25 | 1.3.2 | **SD4 CSA for programming consultant services** |  | 28d | 2010-07-05 | 2010-08-11 |  | 0d |  | FP&C Planning | 464h |
| 26 | 1.3.2.1 | Write RFP for Programming |  | 3d | 2010-07-05 | 2010-07-07 | 24 | 0d |  | FP&C Planning | 24h |
| 27 | 1.3.2.2 | Select A/E from IDIQ List |  | 1d | 2010-07-05 | 2010-07-05 | 26SS | 2d |  | FP&C Planning | 8h |
| 28 | 1.3.2.3 | Issue RFP to A/E Firm |  | 1d | 2010-07-08 | 2010-07-08 | 26, 27 | 0d |  | FP&C Planning | 8h |
| 29 | 1.3.2.4 | A/E Prepare RFP Response |  | 10d | 2010-07-08 | 2010-07-21 | 28SS | 0d |  | A/E (Programming) | 80h |
| 30 | 1.3.2.5 | Negotiate Fee/Agreement |  | 5d | 2010-07-22 | 2010-07-28 | 29 | 0d |  | FP&C Planning | 40h |
| 31 | 1.3.2.6 | Issue & Execute Agreement |  | 10d | 2010-07-29 | 2010-08-11 | 30 | 0d |  | FP&C Planning | 80h |
| 32 | 1.3.3 | SD24 NTP to programming CSA Vendor | milestone | 0d | 2010-08-11 | 2010-08-11 | 31 | 0d |  | FP&C Planning |  |
| 33 | 1.3.4 | **SD26 Project Program Developed** |  | 35d | 2010-08-11 | 2010-09-29 | 24, 31, 32 | 0d |  | FP&C Planning | 720h |
| 34 | 1.3.4.1 | Programming Kick-off Meeting | milestone | 0d | 2010-08-11 | 2010-08-11 | 30FS-5d | 0d |  | FP&C Planning |  |
| 35 | 1.3.4.2 | A/E prepares basic documents & program narrative |  | 30d | 2010-08-12 | 2010-09-22 | 34 | 0d |  | A/E (Programming) | 240h |
| 36 | 1.3.4.3 | Space inventory & confirmation |  | 10d | 2010-09-09 | 2010-09-22 | 35FS-10d | 0d |  | A/E (Programming) | 80h |
| 37 | 1.3.4.4 | Equipment/Furniture inventory & confirmation |  | 10d | 2010-09-09 | 2010-09-22 | 36SS | 0d |  | A/E (Programming) | 80h |
| 38 | 1.3.4.5 | Project Control Budget/Milestone Schedule Confirmation |  | 5d | 2010-09-23 | 2010-09-29 | 37 | 0d |  | FP&C Sr. PM | 40h |
| 39 | 1.3.5 | SD29 Approval Meeting with User and Client on program | milestone | 0d | 2010-09-29 | 2010-09-29 | 38 | 0d |  | FP&C Sr. PM |  |
| 40 | 1.3.6 | SD31 Project Control Budget and Schedule Developed based upon program & Client input |  | 5d | 2010-09-30 | 2010-10-06 | 39 | 0d |  | FP&C Sr. PM | 40h |
| 41 | 1.3.7 | ED Approved Project to Move Forward | milestone | 0d | 2010-10-06 | 2010-10-06 | 40 | 0d |  | FP&C Exec Director |  |
| 42 | 1.4 | **STEP 3 SCOPE APPROVAL** |  | 95d | 2010-10-07 | 2011-02-16 |  | 211d |  |  | 1440h |
| 43 | 1.4.1 | SA2 Business Services Obtains Funding Sources & Notifies PPM that account is created |  | 5d | 2010-10-07 | 2010-10-13 | 41 | 177d | 0d | Business Services | 40h |
| 44 | 1.4.2 | Does Project Effect Land or Exterior Façade Changes? (YES Go to SA4/ NO Go to ?) | milestone | 0d | 2010-10-13 | 2010-10-13 | 43 | 177d | 0d | FP&C Sr. PM |  |
| 45 | 1.4.3 | SA4 CFPC Site Review/Approval (Projects > $4M & Land or Exterior Façade Changes) |  | 5d | 2010-10-14 | 2010-10-20 | 44 | 177d | 0d | FP&C Sr. PM | 40h |
| 46 | 1.4.4 | **SA6 Board Approval Process (Req'd. for Projects > $4M)** |  | 35d | 2010-10-21 | 2010-12-08 | 45 | 211d |  | FP&C Exec Director | 560h |
| 47 | 1.4.4.1 | BoR agenda item prep & submission |  | 5d | 2010-10-21 | 2010-10-27 | 45 | 177d | 0d | FP&C Planning | 40h |
| 48 | 1.4.4.2 | BoR review and approval |  | 30d | 2010-10-28 | 2010-12-08 | 47 | 177d | 0d | FP&C Exec Director | 240h |

| ID | WBS | Task | Type | Duration | Start | Finish | Predecessors | Total slack | Free slack | Resources | Work |
| --- | --- | --- | --- | --- | --- | --- | --- | --- | --- | --- | --- |
| 49 | 1.4.5 | **THECB Approval (Req'd. for Projects > $4M) [MUST OCCUR BEFORE STEP 6]** |  | 50d | 2010-12-09 | 2011-02-16 | 48 | 211d |  | FP&C Exec Director | 800h |
| 50 | 1.4.5.1 | Create THECB Draft Application (internal FP&C) |  | 10d | 2010-12-09 | 2010-12-22 | 48 | 177d | 0d | FP&C Facilities Info | 80h |
| 51 | 1.4.5.2 | Submit THECB Application (internal FP&C) | milestone | 0d | 2010-12-22 | 2010-12-22 | 50 | 177d | 0d | FP&C Facilities Info |  |
| 52 | 1.4.5.3 | THECB Project Review & Evaluation Deadline |  | 40d | 2010-12-23 | 2011-02-16 | 51, 50 | 177d | 0d | FP&C Facilities Info | 320h |
| 53 | 1.4.5.4 | THECB Full Board Meeting/Approval | milestone | 0d | 2011-02-16 | 2011-02-16 | 52, 47, 48, 21 | 177d | 0d | FP&C Facilities Info |  |
| 54 | 1.5 | **STEP 4 QUALIFICATIONS BASED SELECTION** |  | 52d | 2010-10-07 | 2010-12-17 |  | 0d |  |  | 1152h |
| 55 | 1.5.1 | **Step 4 Design Team Selection Process (Can occur parallel to Programming effort or after ED approvel to move forward)** |  | 52d | 2010-10-07 | 2010-12-17 |  | 0d |  | FP&C Exec Director | 1152h |
| 56 | 1.5.1.1 | **DT1 Write RFQ & Evaluation Criteria** |  | 37d | 2010-10-07 | 2010-11-26 | 41 | 0d |  | FP&C Sr. PM | 608h |
| 57 | 1.5.1.1.1 | DT4 ED Approves RFQ |  | 5d | 2010-10-07 | 2010-10-13 | 41 | 0d |  | FP&C Exec Director | 40h |
| 58 | 1.5.1.1.2 | DT5 OGC Reviews and Approves RFQ | milestone | 0d | 2010-10-13 | 2010-10-13 | 57 | 0d |  | OGC |  |
| 59 | 1.5.1.1.3 | DT9 Post RFQ on ESBD |  | 17d | 2010-10-14 | 2010-11-05 | 58 | 0d |  | Purchasing | 136h |
| 60 | 1.5.1.1.4 | DT10 Pre-submittal conference |  | 5d | 2010-10-28 | 2010-11-03 | 59SS+10d | 0d |  | Purchasing | 40h |
| 61 | 1.5.1.1.5 | DT12 Purchasing/Business Distribute RFQ responses to committee |  | 1d | 2010-11-11 | 2010-11-11 | 60FS+5d | 0d |  | Business Services | 8h |
| 62 | 1.5.1.1.6 | DT14 Evaluate and rank RFQ submittals |  | 8d | 2010-11-12 | 2010-11-23 | 61 | 0d |  | FP&C Sr. PM | 64h |
| 63 | 1.5.1.1.7 | DT18 Select short list |  | 3d | 2010-11-24 | 2010-11-26 | 62 | 1d | 0d | FP&C Sr. PM | 24h |
| 64 | 1.5.1.2 | **DT21 Conduct interviews** |  | 2d | 2010-11-29 | 2010-11-30 | 63 | 0d |  | FP&C Sr. PM | 24h |
| 65 | 1.5.1.2.1 | DT22 Send Committee evaluations to purchasing |  | 1d | 2010-11-29 | 2010-11-29 | 63 | 1d |  | FP&C Sr. PM | 8h |
| 66 | 1.5.1.2.2 | DT25 Purchasing drafts recommendation and sendt o EVP for approval | milestone | 0d | 2010-11-30 | 2010-11-30 | 62FS+5d, 65 | 0d |  | Purchasing |  |
| 67 | 1.5.1.3 | DT26 Purchasing Notifies Successful Vendor |  | 3d | 2010-12-01 | 2010-12-03 | 66 | 0d |  | UH AVP/AVC | 24h |
| 68 | 1.5.1.4 | DT29 Fee Proposal Confirmed with Vendor |  | 10d | 2010-12-06 | 2010-12-17 | 67 | 0d |  | FP&C Sr. PM | 80h |
| 69 | 1.6 | **STEP 4 DESIGN PROCESS** |  | 174d | 2010-12-17 | 2011-08-18 |  | 0d |  |  | 2800h |
| 70 | 1.6.1 | **D1 Pre Design** |  | 0d | 2010-12-17 | 2010-12-17 | 68 | 0d |  | FP&C Sr. PM |  |
| 71 | 1.6.1.1 | D1 Design Kick-off Meeting & Confirm Deliverables | milestone | 0d | 2010-12-17 | 2010-12-17 | 68 | 0d |  | FP&C Sr. PM |  |
| 72 | 1.6.1.2 | D2 NTP to Commence Design | milestone | 0d | 2010-12-17 | 2010-12-17 | 71 | 0d |  | FP&C Sr. PM |  |

| ID | WBS | Task | Type | Duration | Start | Finish | Predecessors | Total slack | Resources | Work |
| --- | --- | --- | --- | --- | --- | --- | --- | --- | --- | --- |
| 73 | 1.6.2 | **D3 Schematic Design** |  | 42d | 2010-12-20 | 2011-02-15 | 72 | 0d | FP&C Sr. PM | 672h |
| 74 | 1.6.2.1 | D4 Issue 95% SD for Review & Comment |  | 30d | 2010-12-20 | 2011-01-28 | 72 | 0d | A/E (Design) | 240h |
| 75 | 1.6.2.2 | D8 Prepare budget check based on 95% SD's |  | 10d | 2011-01-31 | 2011-02-11 | 74 | 0d | CM-R | 80h |
| 76 | 1.6.2.3 | D7 Confirm SD compliance w/ approved program |  | 1d | 2011-02-14 | 2011-02-14 | 75 | 0d | A/E (Design) | 8h |
| 77 | 1.6.2.4 | D9 User Sign-off of SD's |  | 1d | 2011-02-15 | 2011-02-15 | 76 | 39d | FP&C Sr. PM | 8h |
| 78 | 1.6.2.5 | D10 Issue NTP for DD phase | milestone | 0d | 2011-02-14 | 2011-02-14 | 76 | 0d | FP&C Sr. PM |  |
| 79 | 1.6.3 | **D11 Design Development** |  | 88d | 2011-02-15 | 2011-06-16 | 78 | 0d | FP&C Sr. PM | 1408h |
| 80 | 1.6.3.1 | D12 FIS develops furniture plan & Room Numbering |  | 10d | 2011-02-15 | 2011-02-28 | 78 | 0d | FP&C Sr. PM | 80h |
| 81 | 1.6.3.2 | D13 Issue 50% DD for Review & Comment |  | 30d | 2011-03-01 | 2011-04-11 | 74, 77FF, 80 | 0d | A/E (Design) | 240h |
| 82 | 1.6.3.3 | D18 Submit for CFPC Design Approval (Projects > $4M) |  | 3d | 2011-04-12 | 2011-04-14 | 81 | 0d | FP&C Sr. PM | 24h |
| 83 | 1.6.3.4 | D22 Issue 95% DD for Review & Comment |  | 30d | 2011-04-15 | 2011-05-26 | 82 | 0d | A/E (Design) | 240h |
| 84 | 1.6.3.5 | D26 Prepare budget check based on 95% DD's |  | 15d | 2011-05-27 | 2011-06-16 | 83 | 0d | CM-R | 120h |
| 85 | 1.6.3.6 | D28 Issue NTP for CD phase | milestone | 0d | 2011-06-16 | 2011-06-16 | 84 | 0d | FP&C Sr. PM |  |
| 86 | 1.6.4 | **D29 Construction Documents** |  | 45d | 2011-06-17 | 2011-08-18 | 85 | 0d | FP&C Sr. PM | 720h |
| 87 | 1.6.4.1 | D37 Issue 50% CD's for Review and Comment |  | 40d | 2011-06-17 | 2011-08-11 | 85 | 0d | A/E (Design) | 320h |
| 88 | 1.6.4.2 | D40 Final Confirmation of Design to Program |  | 5d | 2011-08-12 | 2011-08-18 | 87 | 0d | A/E (Design) | 40h |
| 89 | 1.6.4.3 | D41 Issue 95% CD's for review & comment | milestone | 0d | 2011-08-18 | 2011-08-18 | 88 | 0d | A/E (Design) |  |
| 90 | 1.6.4.4 | Design Complete, Issue 100% CD's for construction | milestone | 0d | 2011-08-18 | 2011-08-18 | 89 | 0d | A/E (Design) |  |
| 91 | 1.7 | **STEP 5 BID/PURCHASE** |  | 70d | 2011-09-02 | 2011-12-08 |  | 0d |  | 1048h |
| 92 | 1.7.1 | **Step 5 Contractor CSP Selection Process** |  | 70d | 2011-09-02 | 2011-12-08 | 90 | 0d | FP&C Sr. PM | 1048h |
| 93 | 1.7.1.1 | **CSP2 Write RFP and evaluation criteria [RFP PROCESS]** |  | 32d | 2011-09-02 | 2011-10-17 | 90 | 0d | FP&C Sr. PM | 320h |
| 94 | 1.7.1.1.1 | CSP4 ED Approves RFP |  | 5d | 2011-09-02 | 2011-09-08 | 90FS+10d | 0d | FP&C Exec Director | 40h |
| 95 | 1.7.1.1.2 | CSP5 OGC Reviews and Approves RFP |  | 3d | 2011-09-09 | 2011-09-13 | 94 | 0d | OGC | 24h |
| 96 | 1.7.1.1.3 | CSP9 Purchasing Posts RFP to ESBD | milestone | 0d | 2011-09-14 | 2011-09-14 | 95FS+1d | 0d | Purchasing |  |
| 97 | 1.7.1.1.4 | CSP14 Purchasing/Business Distribute RFQ responses to committee | milestone | 0d | 2011-10-12 | 2011-10-12 | 96FS+20d | 0d | Business Services |  |
| 98 | 1.7.1.1.5 | CSP16 Purchasing Notifies Shortlisted firms of Interview | milestone | 0d | 2011-10-17 | 2011-10-17 | 97FS+3d | 0d | Purchasing |  |

| ID | WBS | Task | Type | Duration | Start | Finish | Predecessors | Total slack | Free slack | Resources | Work |
| --- | --- | --- | --- | --- | --- | --- | --- | --- | --- | --- | --- |
| 99 | 1.7.1.2 | **CSP19 Conduct interviews** |  | 5d | 2011-10-24 | 2011-10-31 | 98 | 0d |  | FP&C Sr. PM | 64h |
| 100 | 1.7.1.2.1 | CSP20 Send Committee evaluations to purchasing | milestone | 0d | 2011-10-24 | 2011-10-24 | 98FS+5d | 0d |  | FP&C Sr. PM |  |
| 101 | 1.7.1.2.2 | CSP23 Purchasing drafts recommendation and sendt o EVP for approval | milestone | 0d | 2011-10-26 | 2011-10-26 | 100FS+2d | 0d |  | Purchasing |  |
| 102 | 1.7.1.2.3 | CSP24 Purchasing Notifies Successful Vendor |  | 3d | 2011-10-27 | 2011-10-31 | 101 | 0d |  | Purchasing | 24h |
| 103 | 1.7.1.3 | CSP25 PM finalizes contract terms with successful vendor |  | 10d | 2011-11-01 | 2011-11-14 | 102 | 0d |  | FP&C Sr. PM | 80h |
| 104 | 1.7.1.4 | CSP33 CC prepares contract and sends for signatures |  | 3d | 2011-11-29 | 2011-12-01 | 103FS+10d | 0d |  | Business Services | 24h |
| 105 | 1.7.1.5 | CSP39 CC sends vendor & PM executed contract & NTP | milestone | 0d | 2011-12-08 | 2011-12-08 | 104FS+5d | 0d |  | Business Services |  |
| 106 | 1.8 | **STEP6 CONSTRUCTION PHASE** |  | 285d | 2011-12-09 | 2013-01-10 |  | 0d |  |  | 4200h |
| 107 | 1.8.1 | C1 PM confirms site ready to commence construction |  | 5d | 2011-12-09 | 2011-12-15 | 53, 105 | 0d |  | FP&C Sr. PM | 40h |
| 108 | 1.8.2 | C2 Conduct Pre-construction/Kick-off Meeting | milestone | 0d | 2011-12-29 | 2011-12-29 | 107FS+10d | 0d |  | FP&C Sr. PM |  |
| 109 | 1.8.3 | C4 PM, PPM review baseline schedule & Schedule of Values |  | 10d | 2011-12-30 | 2012-01-12 | 108 | 0d |  | FP&C Sr. PM | 80h |
| 110 | 1.8.4 | C5 Construction Period |  | 260d | 2012-01-13 | 2013-01-10 | 109 | 0d |  | CM-R | 2080h |
| 111 | 1.8.5 | C6 Perform Inspections during Construction Period |  | 250d | 2012-01-27 | 2013-01-10 | 110SS+10d | 0d |  | Inspection Services | 2000h |
| 112 | 1.9 | **ACTIVATION & CLOSEOUT** |  | 305d? | 2012-11-09 | 2014-01-09 |  | 0d |  |  | 5232h |
| 113 | 1.9.1 | **TAC1 Perform Transition Planning Kick off Meeting** |  | 20d | 2012-11-09 | 2012-12-06 | 110FS-45d | 255d |  | FP&C Sr. PM | 664h |
| 114 | 1.9.1.1 | IT Install & Activation |  | 20d | 2012-11-09 | 2012-12-06 | 110FS-45d | 255d | 0d | FP&C Sr. PM | 160h |
| 115 | 1.9.1.2 | Furniture & Furnishings Coordination |  | 10d | 2012-11-09 | 2012-11-22 | 114SS | 265d | 50d | FP&C Sr. PM | 80h |
| 116 | 1.9.1.3 | Keying Coordination |  | 20d | 2012-11-09 | 2012-12-06 | 114SS | 255d | 40d | FP&C Sr. PM | 160h |
| 117 | 1.9.1.4 | Grounds Coordination |  | 3d | 2012-11-09 | 2012-11-13 | 114SS | 272d | 57d | FP&C Sr. PM | 24h |
| 118 | 1.9.1.5 | Coordinate building turnover with UH Facilities Mgmt. |  | 10d | 2012-11-09 | 2012-11-22 | 114SS | 265d | 50d | FP&C Sr. PM | 80h |
| 119 | 1.9.2 | **TAC2 Perform Commissioning, Inspections & Equipment Certifications** |  | 25d | 2012-11-30 | 2013-01-03 | 110FS-30d | 5d |  | FP&C Sr. PM | 680h |
| 120 | 1.9.2.1 | Building occupancy certification/Fire Marshall inspections |  | 15d | 2012-11-30 | 2012-12-20 | 110FS-30d | 267d | 10d | CM-R | 120h |
| 121 | 1.9.2.2 | Building test & balance |  | 20d | 2012-11-30 | 2012-12-27 | 110FF-30d | 5d | 0d | FP&C Sr. PM | 160h |
| 122 | 1.9.2.3 | Building systems commissioning & testing |  | 20d | 2012-11-30 | 2012-12-27 | 110FF-30d | 5d | 0d | FP&C Sr. PM | 160h |
| 123 | 1.9.2.4 | BAS/DDC commissioning sign off/acceptance |  | 5d | 2012-12-28 | 2013-01-03 | 121, 122 | 5d | 0d | FP&C Sr. PM | 40h |

| ID | WBS | Task | Type | Duration | Start | Finish | Predecessors | Total slack | Free slack | Resources | Work |
| --- | --- | --- | --- | --- | --- | --- | --- | --- | --- | --- | --- |
| 124 | 1.9.3 | **TAC3 Perform Substantial Completion Activities** |  | 25d | 2012-12-27 | 2013-01-31 |  | 10d |  | FP&C Sr. PM | 320h |
| 125 | 1.9.3.1 | Confirm Inspection Deficiencies Completed | milestone | 0d | 2012-12-27 | 2012-12-27 | 110FF-10d | 225d | 10d | Inspection Services |  |
| 126 | 1.9.3.2 | Substantial Completion | milestone | 0d | 2013-01-10 | 2013-01-10 | 110, 123, 111 | 0d |  | FP&C Sr. PM |  |
| 127 | 1.9.3.3 | Punch List Reconciliation |  | 15d | 2013-01-11 | 2013-01-31 | 126, 125 | 215d | 0d | CM-R | 120h |
| 128 | 1.9.4 | **TAC4 Install Signage, Wayfinding, Furniture & Art** |  | 11d? | 2013-01-11 | 2013-01-25 | 126 | 220d |  | FP&C Sr. PM | 256h |
| 129 | 1.9.4.1 | Install Signage & Wayfinding |  | 10d | 2013-01-11 | 2013-01-24 | 126 | 220d | 5d | FP&C Sr. PM | 80h |
| 130 | 1.9.4.2 | Furniture & Furnishings move-in |  | 10d | 2013-01-11 | 2013-01-24 | 126 | 220d | 0d | FP&C Sr. PM | 80h |
| 131 | 1.9.4.3 | Install Art |  | 1d? | 2013-01-25 | 2013-01-25 | 130 | 249d |  | Art Committee | 8h |
| 132 | 1.9.5 | **TAC5 Building Systems Training** |  | 5d | 2013-01-04 | 2013-01-10 | 123 | 257d |  | FP&C Sr. PM | 104h |
| 133 | 1.9.5.1 | Systems Training of FM by Contractor |  | 3d | 2013-01-04 | 2013-01-08 | 123 | 259d | 37d | CM-R | 24h |
| 134 | 1.9.5.2 | Life Safety Training by Contractor |  | 5d | 2013-01-04 | 2013-01-10 | 120 | 257d | 35d | CM-R | 40h |
| 135 | 1.9.6 | **TAC6 Contractor Performs Final Completion Activities** |  | 30d | 2013-01-31 | 2013-03-14 | 110, 114, 115, 118, 121, 122, 123, 126, 127, 130, 129, 116, 117 | 215d |  | FP&C Sr. PM | 480h |
| 136 | 1.9.6.1 | Final Occupancy | milestone | 0d | 2013-01-31 | 2013-01-31 | 110, 114, 115, 118, 121, 122, 123, 126, 127, 130, 129, 116, 117 | 215d | 0d | FP&C Sr. PM |  |
| 137 | 1.9.6.2 | 1st Day of Operations by End User/Client | milestone | 0d | 2013-01-31 | 2013-01-31 | 136 | 215d | 0d | FP&C Sr. PM |  |
| 138 | 1.9.6.3 | Conduct TDLR final inspection |  | 30d | 2013-02-01 | 2013-03-14 | 137 | 215d |  | A/E (Design) | 240h |
| 139 | 1.9.7 | **TAC7 Perform Administrative Closeout** |  | 20d | 2013-02-01 | 2013-02-28 | 136 | 222d |  | FP&C Sr. PM | 360h |
| 140 | 1.9.7.1 | Construction Closeout Documents Complete |  | 20d | 2013-02-01 | 2013-02-28 | 136 | 222d | 0d | CM-R | 160h |
| 141 | 1.9.7.2 | Final Program Space Allocation Updated with BIS |  | 5d | 2013-02-01 | 2013-02-07 | 136 | 240d |  | Business Services | 40h |
| 142 | 1.9.8 | **TAC8 Perform Financial Closeout** |  | 23d | 2013-02-01 | 2013-03-05 | 136 | 222d |  | FP&C Sr. PM | 368h |
| 143 | 1.9.8.1 | Conduct Final Construction Audit |  | 20d | 2013-02-01 | 2013-02-28 | 136 | 222d | 0d | FP&C Sr. PM | 160h |
| 144 | 1.9.8.2 | Release Contractor Retainage |  | 3d | 2013-03-01 | 2013-03-05 | 143, 133, 134, 140 | 222d | 0d | FP&C Sr. PM | 24h |
| 145 | 1.9.9 | **TAC9 Warranty Period** |  | 245d | 2013-02-01 | 2014-01-09 | 143SS | 0d |  | FP&C Sr. PM | 2000h |
| 146 | 1.9.9.1 | Confirm Contractor Insurance Valid for Warranty Period | milestone | 0d | 2013-02-01 | 2013-02-01 | 143SS | 225d |  | Business Services |  |
| 147 | 1.9.9.2 | 11 Month Inspection |  | 5d | 2013-12-13 | 2013-12-19 | 126FS+240d, 146 | 0d |  | FP&C Sr. PM | 40h |
| 148 | 1.9.9.3 | Warranty Repairs Completed | milestone | 0d | 2014-01-09 | 2014-01-09 | 147SS+20d | 0d |  | Contractor |  |
| 149 | 1.9.10 | END OF PROJECT | milestone | 0d | 2014-01-09 | 2014-01-09 | 148, 131, 138, 141, 144 | 0d |  | FP&C Sr. PM |  |
