# Major Projects Schedule Template

Schedule from MS Project, 2010-06-07 to 2013-11-26.
UH

## Calendars

- Standard: Mon-Fri 08:00-12:00, 13:00-17:00; Sat-Sun off.

## Resources

| Resource |
| --- |
| A/E (Design) |
| CM-R |
| FP&C Sr. PM |
| FP&C PPM |
| UH Client |
| UH AVP/AVC |
| FP&C Exec Director |
| UH Pres/Chancellor |
| A/E (Programming) |
| UH Fire Marshal |
| Project Team |
| FP&C Planning |
| Purchasing |
| FP&C Facilities Info |
| 59 |
| Inspection Services |
| Art Committee |
| Business Services |
| OGC |
| Contractor |

## Schedule

| ID | WBS | Task | Type | Duration | Start | Finish | Predecessors | Total slack | Resources | Work |
| --- | --- | --- | --- | --- | --- | --- | --- | --- | --- | --- |
| 1 | 1 | **PROJECT DELIVERY SCHEDULE TEMPLATE (DESIGN BUILD)** |  | 907d? | 2010-06-07 | 2013-11-26 |  | 0d |  | 16688h |
| 2 | 1.1 | **PROJECT MILESTONES** |  | 685d | 2010-06-07 | 2013-01-18 |  | 222d |  |  |
| 3 | 1.1.1 | Project Initiation | milestone | 0d | 2010-06-07 | 2010-06-07 | 23SS | 940d | UH Client |  |
| 4 | 1.1.2 | Programming Kick-off | milestone | 0d | 2010-08-11 | 2010-08-11 | 36SS | 892d | FP&C Planning |  |
| 5 | 1.1.3 | Programming Complete | milestone | 0d | 2010-10-06 | 2010-10-06 | 43SS | 852d | FP&C Exec Director |  |
| 6 | 1.1.4 | CFPC Site Approval (Req'd. for Projects > $4M) | milestone | 0d | 2010-10-14 | 2010-10-14 | 47SS | 847d | FP&C Exec Director |  |
| 7 | 1.1.5 | BoR Agenda Item Due Date (Req'd. for Projects > $4M) | milestone | 0d | 2010-10-21 | 2010-10-21 | 49SS | 842d | FP&C Planning |  |
| 8 | 1.1.6 | BoR Approval (Req'd. for Projects > $4M) | milestone | 0d | 2010-10-28 | 2010-10-28 | 50SS | 837d | FP&C Exec Director |  |
| 9 | 1.1.7 | Design Kick-off | milestone | 0d | 2011-02-23 | 2011-02-23 | 79SS | 719d | FP&C Sr. PM |  |
| 10 | 1.1.8 | THECB Application Due Date (Req'd. for Projects > $4M) | milestone | 0d | 2010-12-22 | 2010-12-22 | 53SS | 797d | FP&C Facilities Info |  |
| 11 | 1.1.9 | THECB Approval (Req'd. for Projects > $4M) | milestone | 0d | 2011-02-16 | 2011-02-16 | 55SS | 757d | FP&C Facilities Info |  |
| 12 | 1.1.10 | Schematic Design Complete | milestone | 0d | 2011-04-21 | 2011-04-21 | 86SS | 678d | FP&C Sr. PM |  |
| 13 | 1.1.11 | CFPC Design Approval (Req'd. for Projects > $4M) | milestone | 0d | 2010-10-14 | 2010-10-14 | 47SS | 814d | FP&C Sr. PM |  |
| 14 | 1.1.12 | Design Development Complete | milestone | 0d | 2011-08-23 | 2011-08-23 | 93SS | 590d | FP&C Sr. PM |  |
| 15 | 1.1.13 | Design Complete | milestone | 0d | 2011-10-25 | 2011-10-25 | 98SS | 545d | A/E (Design) |  |
| 16 | 1.1.14 | Issue 30% CD's for GMP | milestone | 0d | 2010-06-07 | 2010-06-07 |  | 907d | A/E (Design) |  |
| 17 | 1.1.15 | GMP Approved | milestone | 0d | 2010-06-07 | 2010-06-07 |  | 907d | FP&C Sr. PM |  |
| 18 | 1.1.16 | Construction NTP Issued | milestone | 0d | 2010-06-07 | 2010-06-07 |  | 907d | FP&C Sr. PM |  |
| 19 | 1.1.17 | Substantial Completion | milestone | 0d | 2012-11-27 | 2012-11-27 | 120 | 260d | FP&C Sr. PM |  |
| 20 | 1.1.18 | Final Occupancy | milestone | 0d | 2012-12-18 | 2012-12-18 | 130 | 245d | FP&C Sr. PM |  |
| 21 | 1.1.19 | Project Final Closeout | milestone | 0d | 2013-01-18 | 2013-01-18 | 138 | 222d | FP&C Sr. PM |  |
| 22 | 1.2 | **STEP 1 NEED DEVELOPMENT** |  | 15d | 2010-06-07 | 2010-06-25 |  | 0d |  | 120h |
| 23 | 1.2.1 | ND1 Electronic Project Request Form (MCPRF) submitted | milestone | 0d | 2010-06-07 | 2010-06-07 |  | 0d | FP&C Sr. PM |  |
| 24 | 1.2.2 | ND4 Preliminary Assessment |  | 15d | 2010-06-07 | 2010-06-25 | 23 | 0d | FP&C Exec Director | 120h |

| ID | WBS | Task | Type | Duration | Start | Finish | Predecessors | Total slack | Free slack | Resources | Work |
| --- | --- | --- | --- | --- | --- | --- | --- | --- | --- | --- | --- |
| 25 | 1.3 | **STEP 2 SCOPE DEVELOPMENT** |  | 73d | 2010-06-28 | 2010-10-06 | 24 | 0d |  |  | 1264h |
| 26 | 1.3.1 | SD1 PFA Form complete & Obtain Seed Funding |  | 5d | 2010-06-28 | 2010-07-02 |  | 0d |  | Business Services | 40h |
| 27 | 1.3.2 | **SD4 CSA for programming consultant services** |  | 28d | 2010-07-05 | 2010-08-11 |  | 0d |  | FP&C Planning | 464h |
| 28 | 1.3.2.1 | Write RFP for Programming |  | 3d | 2010-07-05 | 2010-07-07 | 26 | 0d |  | FP&C Planning | 24h |
| 29 | 1.3.2.2 | Select A/E from IDIQ List |  | 1d | 2010-07-05 | 2010-07-05 | 28SS | 2d |  | FP&C Planning | 8h |
| 30 | 1.3.2.3 | Issue RFP to A/E Firm |  | 1d | 2010-07-08 | 2010-07-08 | 28, 29 | 0d |  | FP&C Planning | 8h |
| 31 | 1.3.2.4 | A/E Prepare RFP Response |  | 10d | 2010-07-08 | 2010-07-21 | 30SS | 0d |  | A/E (Programming) | 80h |
| 32 | 1.3.2.5 | Negotiate Fee/Agreement |  | 5d | 2010-07-22 | 2010-07-28 | 31 | 0d |  | FP&C Planning | 40h |
| 33 | 1.3.2.6 | Issue & Execute Agreement |  | 10d | 2010-07-29 | 2010-08-11 | 32 | 0d |  | FP&C Planning | 80h |
| 34 | 1.3.3 | SD24 NTP to programming CSA Vendor | milestone | 0d | 2010-08-11 | 2010-08-11 | 33 | 0d |  | FP&C Planning |  |
| 35 | 1.3.4 | **SD26 Project Program Developed** |  | 35d | 2010-08-11 | 2010-09-29 | 26, 33, 34 | 0d |  | FP&C Planning | 720h |
| 36 | 1.3.4.1 | Programming Kick-off Meeting | milestone | 0d | 2010-08-11 | 2010-08-11 | 32FS-5d | 0d |  | FP&C Planning |  |
| 37 | 1.3.4.2 | A/E prepares basic documents & program narrative |  | 30d | 2010-08-12 | 2010-09-22 | 36 | 0d |  | A/E (Programming) | 240h |
| 38 | 1.3.4.3 | Space inventory & confirmation |  | 10d | 2010-09-09 | 2010-09-22 | 37FS-10d | 0d |  | A/E (Programming) | 80h |
| 39 | 1.3.4.4 | Equipment/Furniture inventory & confirmation |  | 10d | 2010-09-09 | 2010-09-22 | 38SS | 0d |  | A/E (Programming) | 80h |
| 40 | 1.3.4.5 | Project Control Budget/Milestone Schedule Confirmation |  | 5d | 2010-09-23 | 2010-09-29 | 39 | 0d |  | FP&C Sr. PM | 40h |
| 41 | 1.3.5 | SD29 Approval Meeting with User and Client on program | milestone | 0d | 2010-09-29 | 2010-09-29 | 40 | 0d |  | FP&C Sr. PM |  |
| 42 | 1.3.6 | SD31 Project Control Budget and Schedule Developed based upon program & Client input |  | 5d | 2010-09-30 | 2010-10-06 | 41 | 0d |  | FP&C Sr. PM | 40h |
| 43 | 1.3.7 | ED Approved Project to Move Forward | milestone | 0d | 2010-10-06 | 2010-10-06 | 42 | 0d |  | FP&C Exec Director |  |
| 44 | 1.4 | **STEP 3 SCOPE APPROVAL** |  | 95d | 2010-10-07 | 2011-02-16 |  | 5d |  |  | 1440h |
| 45 | 1.4.1 | SA2 Business Services Obtains Funding Sources & Notifies PPM that account is created |  | 5d | 2010-10-07 | 2010-10-13 | 43 | 5d | 0d | Business Services | 40h |
| 46 | 1.4.2 | Does Project Effect Land or Exterior Façade Changes? (YES Go to SA4/ NO Go to ?) | milestone | 0d | 2010-10-13 | 2010-10-13 | 45 | 5d | 0d | FP&C Sr. PM |  |
| 47 | 1.4.3 | SA4 CFPC Site Review/Approval (Projects > $4M & Land or Exterior Façade Changes) |  | 5d | 2010-10-14 | 2010-10-20 | 46 | 5d | 0d | FP&C Sr. PM | 40h |
| 48 | 1.4.4 | **SA6 Board Approval Process (Req'd. for Projects > $4M)** |  | 35d | 2010-10-21 | 2010-12-08 | 47 | 5d |  | FP&C Exec Director | 560h |
| 49 | 1.4.4.1 | BoR agenda item prep & submission |  | 5d | 2010-10-21 | 2010-10-27 | 47 | 5d | 0d | FP&C Planning | 40h |
| 50 | 1.4.4.2 | BoR review and approval |  | 30d | 2010-10-28 | 2010-12-08 | 49 | 5d | 0d | FP&C Exec Director | 240h |

| ID | WBS | Task | Type | Duration | Start | Finish | Predecessors | Total slack | Free slack | Resources | Work |
| --- | --- | --- | --- | --- | --- | --- | --- | --- | --- | --- | --- |
| 51 | 1.4.5 | **THECB Approval (Req'd. for Projects > $4M) [MUST OCCUR BEFORE STEP 6]** |  | 50d | 2010-12-09 | 2011-02-16 | 50 | 5d |  | FP&C Exec Director | 800h |
| 52 | 1.4.5.1 | Create THECB Draft Application (internal FP&C) |  | 10d | 2010-12-09 | 2010-12-22 | 50 | 5d | 0d | FP&C Facilities Info | 80h |
| 53 | 1.4.5.2 | Submit THECB Application (internal FP&C) | milestone | 0d | 2010-12-22 | 2010-12-22 | 52 | 5d | 0d | FP&C Facilities Info |  |
| 54 | 1.4.5.3 | THECB Project Review & Evaluation Deadline |  | 40d | 2010-12-23 | 2011-02-16 | 53, 52 | 5d | 0d | FP&C Facilities Info | 320h |
| 55 | 1.4.5.4 | THECB Full Board Meeting/Approval | milestone | 0d | 2011-02-16 | 2011-02-16 | 54, 49, 50, 23 | 5d | 0d | FP&C Facilities Info |  |
| 56 | 1.5 | **STEP 4 QUALIFICATIONS BASED SELECTION** |  | 100d | 2010-10-07 | 2011-02-23 |  | 0d |  |  | 1632h |
| 57 | 1.5.1 | **Step 4 Design Build Team Selection Process** |  | 100d | 2010-10-07 | 2011-02-23 | 43 | 0d |  | FP&C Sr. PM | 1632h |
| 58 | 1.5.1.1 | **DB1 Write RFQ & Evaluation Criteria** |  | 27d | 2010-10-07 | 2010-11-12 | 43 | 0d |  | FP&C Sr. PM | 384h |
| 59 | 1.5.1.1.1 | DB4 ED Approves RFQ |  | 5d | 2010-10-07 | 2010-10-13 | 43 | 0d |  | FP&C Exec Director | 40h |
| 60 | 1.5.1.1.2 | DB5 OGC Reviews and Approves RFQ | milestone | 0d | 2010-10-13 | 2010-10-13 | 59 | 0d |  | OGC |  |
| 61 | 1.5.1.1.3 | DB9 Post RFQ on ESBD |  | 2d | 2010-10-14 | 2010-10-15 | 60 | 0d |  | Purchasing | 16h |
| 62 | 1.5.1.1.4 | DB10 Pre-submittal conference |  | 5d | 2010-10-21 | 2010-10-27 | 61FS+3d | 0d |  | Purchasing | 40h |
| 63 | 1.5.1.1.5 | DB13 Purchasing/Business Distribute RFQ responses to committee |  | 1d | 2010-11-02 | 2010-11-02 | 62FS+3d | 0d |  | Business Services | 8h |
| 64 | 1.5.1.1.6 | DB15 Evaluate and rank RFQ submittals & determines firms to receive RFP |  | 8d | 2010-11-03 | 2010-11-12 | 63 | 0d |  | FP&C Sr. PM | 64h |
| 65 | 1.5.1.2 | **DB19 Write RFP and evaluation criteria [RFP PROCESS]** |  | 25d | 2010-11-29 | 2010-12-31 | 64 | 0d |  | FP&C Sr. PM | 280h |
| 66 | 1.5.1.2.1 | DB20 ED Approves RFP |  | 10d | 2010-11-29 | 2010-12-10 | 64FS+10d | 0d |  | FP&C Exec Director | 80h |
| 67 | 1.5.1.2.2 | DB21 OGC Reviews and Approves RFP | milestone | 0d | 2010-12-10 | 2010-12-10 | 66 | 0d |  | OGC |  |
| 68 | 1.5.1.2.3 | DB25 Purchasing issues RFP to short listed firms | milestone | 0d | 2010-12-17 | 2010-12-17 | 67SS+5d | 0d |  | Purchasing |  |
| 69 | 1.5.1.2.4 | DB29 Purchasing/Business Distribute RFP responses to committee | milestone | 0d | 2010-12-31 | 2010-12-31 | 68FS+10d | 0d |  | Business Services |  |
| 70 | 1.5.1.3 | **DB34 Conduct interviews** |  | 5d | 2011-01-07 | 2011-01-14 | 69 | 0d |  | FP&C Sr. PM | 64h |
| 71 | 1.5.1.3.1 | DB35 Send Committee evaluations to purchasing | milestone | 0d | 2011-01-07 | 2011-01-07 | 69FS+5d | 0d |  | FP&C Sr. PM |  |
| 72 | 1.5.1.3.2 | DB38 Purchasing drafts recommendation and sendt o EVP for approval | milestone | 0d | 2011-01-11 | 2011-01-11 | 71FS+2d | 0d |  | Purchasing |  |
| 73 | 1.5.1.3.3 | DB39 Purchasing Notifies Successful Vendor |  | 3d | 2011-01-12 | 2011-01-14 | 72 | 0d |  | UH AVP/AVC | 24h |
| 74 | 1.5.1.4 | DB40 Fee Proposal Confirmed with Vendor |  | 10d | 2011-01-17 | 2011-01-28 | 73 | 0d |  | FP&C Sr. PM | 80h |
| 75 | 1.5.1.5 | DB47 CC prepares contract and sends for signatures |  | 3d | 2011-02-14 | 2011-02-16 | 74FS+10d | 0d |  | Business Services | 24h |
| 76 | 1.5.1.6 | DB54 CC sends vendor & PM executed contract & NTP | milestone | 0d | 2011-02-23 | 2011-02-23 | 75FS+5d, 55 | 0d |  | Business Services |  |

| ID | WBS | Task | Type | Duration | Start | Finish | Predecessors | Total slack | Resources | Work |
| --- | --- | --- | --- | --- | --- | --- | --- | --- | --- | --- |
| 77 | 1.6 | **STEP 4 DESIGN PROCESS** |  | 174d | 2011-02-23 | 2011-10-25 |  | 0d |  | 2800h |
| 78 | 1.6.1 | **D1 Pre Design** |  | 0d | 2011-02-23 | 2011-02-23 | 76 | 0d | FP&C Sr. PM |  |
| 79 | 1.6.1.1 | D1 Design Kick-off Meeting & Confirm Deliverables | milestone | 0d | 2011-02-23 | 2011-02-23 |  | 0d | FP&C Sr. PM |  |
| 80 | 1.6.1.2 | D2 NTP to Commence Design | milestone | 0d | 2011-02-23 | 2011-02-23 | 79 | 0d | FP&C Sr. PM |  |
| 81 | 1.6.2 | **D3 Schematic Design** |  | 42d | 2011-02-24 | 2011-04-22 | 80 | 0d | FP&C Sr. PM | 672h |
| 82 | 1.6.2.1 | D4 Issue 95% SD for Review & Comment |  | 30d | 2011-02-24 | 2011-04-06 | 80 | 0d | A/E (Design) | 240h |
| 83 | 1.6.2.2 | D8 Prepare budget check based on 95% SD's |  | 10d | 2011-04-07 | 2011-04-20 | 82 | 0d | CM-R | 80h |
| 84 | 1.6.2.3 | D7 Confirm SD compliance w/ approved program |  | 1d | 2011-04-21 | 2011-04-21 | 83 | 0d | A/E (Design) | 8h |
| 85 | 1.6.2.4 | D9 User Sign-off of SD's |  | 1d | 2011-04-22 | 2011-04-22 | 84 | 39d | FP&C Sr. PM | 8h |
| 86 | 1.6.2.5 | D10 Issue NTP for DD phase | milestone | 0d | 2011-04-21 | 2011-04-21 | 84 | 0d | FP&C Sr. PM |  |
| 87 | 1.6.3 | **D11 Design Development** |  | 88d | 2011-04-22 | 2011-08-23 | 86 | 0d | FP&C Sr. PM | 1408h |
| 88 | 1.6.3.1 | D12 FIS develops furniture plan & Room Numbering |  | 10d | 2011-04-22 | 2011-05-05 | 86 | 0d | FP&C Sr. PM | 80h |
| 89 | 1.6.3.2 | D13 Issue 50% DD for Review & Comment |  | 30d | 2011-05-06 | 2011-06-16 | 82, 85FF, 88 | 0d | A/E (Design) | 240h |
| 90 | 1.6.3.3 | D18 Submit for CFPC Design Approval (Projects > $4M) |  | 3d | 2011-06-17 | 2011-06-21 | 89 | 0d | FP&C Sr. PM | 24h |
| 91 | 1.6.3.4 | D22 Issue 95% DD for Review & Comment |  | 30d | 2011-06-22 | 2011-08-02 | 90 | 0d | A/E (Design) | 240h |
| 92 | 1.6.3.5 | D26 Prepare budget check based on 95% DD's |  | 15d | 2011-08-03 | 2011-08-23 | 91 | 0d | CM-R | 120h |
| 93 | 1.6.3.6 | D28 Issue NTP for CD phase | milestone | 0d | 2011-08-23 | 2011-08-23 | 92 | 0d | FP&C Sr. PM |  |
| 94 | 1.6.4 | **D29 Construction Documents** |  | 45d | 2011-08-24 | 2011-10-25 | 93 | 0d | FP&C Sr. PM | 720h |
| 95 | 1.6.4.1 | D37 Issue 50% CD's for Review and Comment |  | 40d | 2011-08-24 | 2011-10-18 | 93 | 0d | A/E (Design) | 320h |
| 96 | 1.6.4.2 | D40 Final Confirmation of Design to Program |  | 5d | 2011-10-19 | 2011-10-25 | 95 | 0d | A/E (Design) | 40h |
| 97 | 1.6.4.3 | D41 Issue 95% CD's for review & comment | milestone | 0d | 2011-10-25 | 2011-10-25 | 96 | 0d | A/E (Design) |  |
| 98 | 1.6.4.4 | Design Complete, Issue 100% CD's for construction | milestone | 0d | 2011-10-25 | 2011-10-25 | 97 | 0d | A/E (Design) |  |
| 99 | 1.7 | STEP 5 BID/PURCHASE |  | 1d? | 2010-06-07 | 2010-06-07 |  | 906d |  |  |
| 100 | 1.8 | **STEP6 CONSTRUCTION PHASE** |  | 285d | 2011-10-26 | 2012-11-27 |  | 0d |  | 4200h |
| 101 | 1.8.1 | C1 PM confirms site ready to commence construction |  | 5d | 2011-10-26 | 2011-11-01 | 55, 98 | 0d | FP&C Sr. PM | 40h |
| 102 | 1.8.2 | C2 Conduct Pre-construction/Kick-off Meeting | milestone | 0d | 2011-11-15 | 2011-11-15 | 101FS+10d | 0d | FP&C Sr. PM |  |
| 103 | 1.8.3 | C4 PM, PPM review baseline schedule & Schedule of Values |  | 10d | 2011-11-16 | 2011-11-29 | 102 | 0d | FP&C Sr. PM | 80h |
| 104 | 1.8.4 | C5 Construction Period |  | 260d | 2011-11-30 | 2012-11-27 | 103 | 0d | CM-R | 2080h |
| 105 | 1.8.5 | C6 Perform Inspections during Construction Period |  | 250d | 2011-12-14 | 2012-11-27 | 104SS+10d | 0d | Inspection Services | 2000h |

| ID | WBS | Task | Type | Duration | Start | Finish | Predecessors | Total slack | Free slack | Resources | Work |
| --- | --- | --- | --- | --- | --- | --- | --- | --- | --- | --- | --- |
| 106 | 1.9 | **ACTIVATION & CLOSEOUT** |  | 305d? | 2012-09-26 | 2013-11-26 |  | 0d |  |  | 5232h |
| 107 | 1.9.1 | **TAC1 Perform Transition Planning Kick off Meeting** |  | 20d | 2012-09-26 | 2012-10-23 | 104FS-45d | 255d |  | FP&C Sr. PM | 664h |
| 108 | 1.9.1.1 | IT Install & Activation |  | 20d | 2012-09-26 | 2012-10-23 | 104FS-45d | 255d | 0d | FP&C Sr. PM | 160h |
| 109 | 1.9.1.2 | Furniture & Furnishings Coordination |  | 10d | 2012-09-26 | 2012-10-09 | 108SS | 265d | 50d | FP&C Sr. PM | 80h |
| 110 | 1.9.1.3 | Keying Coordination |  | 20d | 2012-09-26 | 2012-10-23 | 108SS | 255d | 40d | FP&C Sr. PM | 160h |
| 111 | 1.9.1.4 | Grounds Coordination |  | 3d | 2012-09-26 | 2012-09-28 | 108SS | 272d | 57d | FP&C Sr. PM | 24h |
| 112 | 1.9.1.5 | Coordinate building turnover with UH Facilities Mgmt. |  | 10d | 2012-09-26 | 2012-10-09 | 108SS | 265d | 50d | FP&C Sr. PM | 80h |
| 113 | 1.9.2 | **TAC2 Perform Commissioning, Inspections & Equipment Certifications** |  | 25d | 2012-10-17 | 2012-11-20 | 104FS-30d | 5d |  | FP&C Sr. PM | 680h |
| 114 | 1.9.2.1 | Building occupancy certification/Fire Marshall inspections |  | 15d | 2012-10-17 | 2012-11-06 | 104FS-30d | 267d | 10d | CM-R | 120h |
| 115 | 1.9.2.2 | Building test & balance |  | 20d | 2012-10-17 | 2012-11-13 | 104FF-30d | 5d | 0d | FP&C Sr. PM | 160h |
| 116 | 1.9.2.3 | Building systems commissioning & testing |  | 20d | 2012-10-17 | 2012-11-13 | 104FF-30d | 5d | 0d | FP&C Sr. PM | 160h |
| 117 | 1.9.2.4 | BAS/DDC commissioning sign off/acceptance |  | 5d | 2012-11-14 | 2012-11-20 | 115, 116 | 5d | 0d | FP&C Sr. PM | 40h |
| 118 | 1.9.3 | **TAC3 Perform Substantial Completion Activities** |  | 25d | 2012-11-13 | 2012-12-18 |  | 10d |  | FP&C Sr. PM | 320h |
| 119 | 1.9.3.1 | Confirm Inspection Deficiencies Completed | milestone | 0d | 2012-11-13 | 2012-11-13 | 104FF-10d | 225d | 10d | Inspection Services |  |
| 120 | 1.9.3.2 | Substantial Completion | milestone | 0d | 2012-11-27 | 2012-11-27 | 104, 117, 105 | 0d |  | FP&C Sr. PM |  |
| 121 | 1.9.3.3 | Punch List Reconciliation |  | 15d | 2012-11-28 | 2012-12-18 | 120, 119 | 215d | 0d | CM-R | 120h |
| 122 | 1.9.4 | **TAC4 Install Signage, Wayfinding, Furniture & Art** |  | 11d? | 2012-11-28 | 2012-12-12 | 120 | 220d |  | FP&C Sr. PM | 256h |
| 123 | 1.9.4.1 | Install Signage & Wayfinding |  | 10d | 2012-11-28 | 2012-12-11 | 120 | 220d | 5d | FP&C Sr. PM | 80h |
| 124 | 1.9.4.2 | Furniture & Furnishings move-in |  | 10d | 2012-11-28 | 2012-12-11 | 120 | 220d | 0d | FP&C Sr. PM | 80h |
| 125 | 1.9.4.3 | Install Art |  | 1d? | 2012-12-12 | 2012-12-12 | 124 | 249d |  | Art Committee | 8h |
| 126 | 1.9.5 | **TAC5 Building Systems Training** |  | 5d | 2012-11-21 | 2012-11-27 | 117 | 257d |  | FP&C Sr. PM | 104h |
| 127 | 1.9.5.1 | Systems Training of FM by Contractor |  | 3d | 2012-11-21 | 2012-11-23 | 117 | 259d | 37d | CM-R | 24h |
| 128 | 1.9.5.2 | Life Safety Training by Contractor |  | 5d | 2012-11-21 | 2012-11-27 | 114 | 257d | 35d | CM-R | 40h |
| 129 | 1.9.6 | **TAC6 Contractor Performs Final Completion Activities** |  | 30d | 2012-12-18 | 2013-01-29 | 104, 108, 109, 112, 115, 116, 117, 120, 121, 124, 123, 110, 111 | 215d |  | FP&C Sr. PM | 480h |
| 130 | 1.9.6.1 | Final Occupancy | milestone | 0d | 2012-12-18 | 2012-12-18 | 104, 108, 109, 112, 115, 116, 117, 120, 121, 124, 123, 110, 111 | 215d | 0d | FP&C Sr. PM |  |
| 131 | 1.9.6.2 | 1st Day of Operations by End User/Client | milestone | 0d | 2012-12-18 | 2012-12-18 | 130 | 215d | 0d | FP&C Sr. PM |  |
| 132 | 1.9.6.3 | Conduct TDLR final inspection |  | 30d | 2012-12-19 | 2013-01-29 | 131 | 215d |  | A/E (Design) | 240h |

| ID | WBS | Task | Type | Duration | Start | Finish | Predecessors | Total slack | Free slack | Resources | Work |
| --- | --- | --- | --- | --- | --- | --- | --- | --- | --- | --- | --- |
| 133 | 1.9.7 | **TAC7 Perform Administrative Closeout** |  | 20d | 2012-12-19 | 2013-01-15 | 130 | 222d |  | FP&C Sr. PM | 360h |
| 134 | 1.9.7.1 | Construction Closeout Documents Complete |  | 20d | 2012-12-19 | 2013-01-15 | 130 | 222d | 0d | CM-R | 160h |
| 135 | 1.9.7.2 | Final Program Space Allocation Updated with BIS |  | 5d | 2012-12-19 | 2012-12-25 | 130 | 240d |  | Business Services | 40h |
| 136 | 1.9.8 | **TAC8 Perform Financial Closeout** |  | 23d | 2012-12-19 | 2013-01-18 | 130 | 222d |  | FP&C Sr. PM | 368h |
| 137 | 1.9.8.1 | Conduct Final Construction Audit |  | 20d | 2012-12-19 | 2013-01-15 | 130 | 222d | 0d | FP&C Sr. PM | 160h |
| 138 | 1.9.8.2 | Release Contractor Retainage |  | 3d | 2013-01-16 | 2013-01-18 | 137, 127, 128, 134 | 222d | 0d | FP&C Sr. PM | 24h |
| 139 | 1.9.9 | **TAC9 Warranty Period** |  | 245d | 2012-12-19 | 2013-11-26 | 137SS | 0d |  | FP&C Sr. PM | 2000h |
| 140 | 1.9.9.1 | Confirm Contractor Insurance Valid for Warranty Period | milestone | 0d | 2012-12-19 | 2012-12-19 | 137SS | 225d |  | Business Services |  |
| 141 | 1.9.9.2 | 11 Month Inspection |  | 5d | 2013-10-30 | 2013-11-05 | 120FS+240d, 140 | 0d |  | FP&C Sr. PM | 40h |
| 142 | 1.9.9.3 | Warranty Repairs Completed | milestone | 0d | 2013-11-26 | 2013-11-26 | 141SS+20d | 0d |  | Contractor |  |
| 143 | 1.9.10 | END OF PROJECT | milestone | 0d | 2013-11-26 | 2013-11-26 | 142, 125, 132, 135, 138 | 0d |  | FP&C Sr. PM |  |
